# EPDP-P2_Project_Plan_20190930

Schedule from MS Project, 2019-03-04 to 2020-10-06, A marks actual dates.

## Calendars

- Standard: Mon-Fri 08:00-12:00, 13:00-17:00; Sat-Sun off. Exceptions (off unless hours are given): 2019-11-02 to 2019-11-03 08:00-12:00, 13:00-17:00.

## Schedule

| ID | WBS | Task | Duration | Start | Finish | Predecessors | Complete | Remaining | Total slack | Constraint |
| --- | --- | --- | --- | --- | --- | --- | --- | --- | --- | --- |
| 1 | 1 | **EPDP - Phase 2 Policy Development** | 419d | 2019-03-04 A | 2020-10-06 |  | 31% | 290.93d | 0d |  |
| 2 | 1.1 | **PROJECT MANAGEMENT** | 419d | 2019-03-04 A | 2020-10-06 |  | 64% | 151.67d | 0d |  |
| 3 | 1.1.1 | Project start confirmed | 1d | 2019-03-04 A | 2019-03-04 A |  | 100% |  |  |  |
| 4 | 1.1.2 | Adopt/Confirm charter | 1d | 2019-03-05 A | 2019-03-05 A | 3 | 100% |  |  |  |
| 5 | 1.1.3 | Confirmation of EPDP Team | 20d | 2019-03-05 A | 2019-04-01 A | 3 | 100% |  |  |  |
| 6 | 1.1.4 | Appointment of EPDP Team Chair | 30d | 2019-03-05 A | 2019-04-15 A | 3 | 100% |  |  |  |
| 7 | 1.1.5 | Appointment of EPDP Liaison to GNSO Council | 5d | 2019-04-16 A | 2019-04-22 A | 6 | 100% |  |  |  |
| 8 | 1.1.6 | Chair / Staff preparations | 12d | 2019-04-16 A | 2019-05-01 A | 6 | 100% |  |  |  |
| 9 | 1.1.7 | **Project Management** | 417d | 2019-03-06 A | 2020-10-06 |  | 61% | 161.2d | 0d |  |
| 10 | 1.1.7.1 | Develop and confirm Project Plan | 90d | 2019-04-16 A | 2019-08-19 A | 6 | 100% |  |  |  |
| 11 | 1.1.7.2 | Adopt iterative work plan(s) | 90d | 2019-04-16 A | 2019-08-19 A | 6 | 100% |  |  |  |
| 12 | 1.1.7.3 | Develop Project status work products and communications | 90d | 2019-04-16 A | 2019-08-19 A | 6 | 100% |  |  |  |
| 13 | 1.1.7.4 | Obtain project plan approval from GNSO Council | 1d | 2019-08-22 A | 2019-08-22 A | 12 | 100% |  |  | start no earlier than 2019-08-22 |
| 14 | 1.1.7.5 | **Leadership Sub team** | 275d | 2019-04-16 A | 2020-04-30 |  | 43% | 156.75d | 93d |  |
| 15 | 1.1.7.5.1 | On-going preparation and planning of EPDP-P2 activities | 275d | 2019-04-16 A | 2020-04-30 | 6 | 43% | 156.75d | 93d |  |
| 16 | 1.1.7.6 | **Project Cost Support Team Sub team** | 360d | 2019-03-06 A | 2020-07-17 |  | 52% | 172.8d | 37d |  |
| 17 | 1.1.7.6.1 | Develop EPDP Fact Sheet | 30d | 2019-04-16 A | 2019-05-27 A | 6 | 100% |  |  |  |
| 18 | 1.1.7.6.2 | Request and acquire preliminary dedicated funds for additional project resources | 20d | 2019-03-06 A | 2019-04-02 A | 4 | 100% |  |  |  |
| 19 | 1.1.7.6.3 | Request and acquire funds for dedicated F2F sessions & facilitation services | 20d | 2019-05-02 A | 2019-05-29 A | 8 | 100% |  |  |  |
| 20 | 1.1.7.6.4 | Request and acquire final dedicated funds for additional project resources | 20d | 2019-08-27 A | 2019-10-08 A | 13 | 100% |  |  |  |
| 21 | 1.1.7.6.5 | On-going financial and resource approvals of EPDP-P2 activities | 360d | 2019-03-06 A | 2020-07-17 | 4 | 40% | 216d | 37d |  |
| 22 | 1.1.7.7 | Close project plan, Factsheet, and transition project to IPT | 20d | 2020-09-09 | 2020-10-06 | 21, 15, 326 |  |  | 0d |  |
| 23 | 1.2 | **EPDP DELIBERATIONS** | 310d | 2019-04-03 A | 2020-06-05 |  | 26% | 229.4d | 87d |  |
| 24 | 1.2.1 | First meeting of EPDP Team | 1d | 2019-05-02 A | 2019-05-02 A | 8 | 100% |  |  |  |
| 25 | 1.2.2 | Understand Charter, organize materials and develop initial approach | 15d | 2019-05-02 A | 2019-05-22 A | 8 | 100% |  |  |  |
| 26 | 1.2.3 | Develop Worksheets for Phase 2 due diligence and organize work by Priority 1 & 2 Topics | 21d | 2019-05-02 A | 2019-05-30 A | 8 | 100% |  |  |  |
| 27 | 1.2.4 | Review prior legal advice memos and formulate potential topics that may require advice | 21d | 2019-05-02 A | 2019-05-30 A | 8 | 100% |  |  |  |
| 28 | 1.2.5 | Develop definitions and terminology | 21d | 2019-05-02 A | 2019-05-30 A | 8 | 100% |  |  |  |

| ID | WBS | Task | Type | Duration | Start | Finish | Predecessors | Complete | Remaining | Total slack | Free slack |
| --- | --- | --- | --- | --- | --- | --- | --- | --- | --- | --- | --- |
| 29 | 1.2.6 | **Input from other SO/ACs & GNSO SG/Cs** |  | 134d | 2019-05-23 A | 2019-11-22 |  | 44% | 75d | 227d |  |
| 30 | 1.2.6.1 | Develop template for input |  | 5d | 2019-05-23 A | 2019-05-29 A | 25 | 100% |  |  |  |
| 31 | 1.2.6.2 | Announce input opportunity |  | 1d | 2019-05-30 A | 2019-05-30 A | 30 | 100% |  |  |  |
| 32 | 1.2.6.3 | Collect and collate input in to Review Tool |  | 28d | 2019-05-31 A | 2019-07-09 A | 31 | 100% |  |  |  |
| 33 | 1.2.6.4 | Group to review input and determine relevance to policy deliberations on issues within scope |  | 100d | 2019-07-10 A | 2019-11-22 | 32 | 25% | 75d | 227d |  |
| 34 | 1.2.7 | **Priority 1 Deliberations** |  | 125d | 2019-05-31 A | 2019-11-19 |  | 39% | 75.91d | 230d |  |
| 35 | 1.2.7.1 | **Requirements, incl. defining user groups, use cases and other criteria to determine similarities and differences** |  | 70d | 2019-05-31 A | 2019-09-05 A |  | 100% |  |  |  |
| 36 | 1.2.7.1.1 | Deliberate Groups to Use Case approach |  | 10d | 2019-06-14 A | 2019-06-27 A | 26 | 100% |  |  |  |
| 37 | 1.2.7.1.2 | Deliberate Single Use Case to establish Template |  | 10d | 2019-06-14 A | 2019-06-27 A | 26 | 100% |  |  |  |
| 38 | 1.2.7.1.3 | **Generate potential Use Cases (refer to 20+ on wiki)** |  | 70d | 2019-05-31 A | 2019-09-05 A | 37 | 100% |  |  |  |
| 39 | 1.2.7.1.3.1 | Confirm Use Case order and groups to consolidate |  | 50d | 2019-06-28 A | 2019-09-05 A |  | 100% |  |  |  |
| 40 | 1.2.7.1.3.2 | Understand Purposes and Legitimate Interest for third party disclosure |  | 10d | 2019-05-31 A | 2019-07-02 A |  | 100% |  |  |  |
| 41 | 1.2.7.1.3.3 | First reading + response |  | 50d | 2019-06-28 A | 2019-09-05 A |  | 100% |  |  |  |
| 42 | 1.2.7.1.3.4 | Deliberate other policy topics as necessary to better inform dedicated time to that topic |  | 30d | 2019-06-28 A | 2019-08-08 A |  | 100% |  |  |  |
| 43 | 1.2.7.1.3.5 | Develop subsequent draft + response |  | 50d | 2019-06-28 A | 2019-09-05 A |  | 100% |  |  |  |
| 44 | 1.2.7.1.3.6 | Second reading + adoption or discard |  | 50d | 2019-06-28 A | 2019-09-05 A |  | 100% |  |  |  |
| 45 | 1.2.7.2 | **SSAD Model & Worksheets & Preliminary Recommendations** |  | 75d | 2019-08-09 A | 2019-11-19 |  | 25% | 56.51d | 230d |  |
| 46 | 1.2.7.2.1 | **Safeguards** |  | 74.5d | 2019-08-09 A | 2019-11-19 |  | 8% | 68.29d | 230.5d |  |
| 47 | 1.2.7.2.1.1 | Review inputs from Requirements and Use Cases |  | 5d | 2019-08-09 A | 2019-09-12 A | 38 | 100% |  |  |  |
| 48 | 1.2.7.2.1.2 | **Understand sub-topics and determine need to deliberate** |  | 10d | 2019-09-12 A | 2019-09-26 |  | 8% | 9.17d | 0d |  |
| 49 | 1.2.7.2.1.2.1 | Query volume limitations | manual | 10d | 2019-09-12 A | 2019-09-26 | 47 | 10% | 9d |  |  |
| 50 | 1.2.7.2.1.2.2 | Code of conduct | manual | 10d | 2019-09-12 A | 2019-09-26 | 47 | 10% | 9d |  |  |
| 51 | 1.2.7.2.1.2.3 | Terms of use / disclosure agreements | manual | 10d | 2019-09-12 A | 2019-09-26 | 47 | 10% | 9d |  |  |
| 52 | 1.2.7.2.1.2.4 | Privacy policies | manual | 10d | 2019-09-12 A | 2019-09-26 | 47 | 10% | 9d |  |  |
| 53 | 1.2.7.2.1.2.5 | Retention and destruction of data | manual | 10d | 2019-09-12 A | 2019-09-26 | 47 | 10% | 9d |  |  |
| 54 | 1.2.7.2.1.2.6 | Service level agreements | manual | 10d | 2019-09-12 | 2019-09-26 | 47 |  |  |  |  |
| 55 | 1.2.7.2.1.2.7 | Transfer of the Data | manual | 10d | 2019-09-12 | 2019-09-26 | 47 |  |  |  |  |
| 56 | 1.2.7.2.1.2.8 | Disclosure of the Data | manual | 10d | 2019-09-12 A | 2019-09-26 | 47 | 10% | 9d |  |  |
| 57 | 1.2.7.2.1.2.9 | Monitoring | manual | 10d | 2019-09-12 A | 2019-09-26 | 47 | 10% | 9d |  |  |
| 58 | 1.2.7.2.1.2.10 | Audit trail | manual | 10d | 2019-09-12 A | 2019-09-26 | 47 | 10% | 9d |  |  |
| 59 | 1.2.7.2.1.2.11 | Retention | manual | 10d | 2019-09-12 A | 2019-09-26 | 47 | 10% | 9d |  |  |
| 60 | 1.2.7.2.1.2.12 | Destruction of data | manual | 10d | 2019-09-12 A | 2019-09-26 | 47 | 10% | 9d |  |  |
| 61 | 1.2.7.2.1.3 | Deliberate policy considerations and determine approach |  | 5d | 2019-09-26 A | 2019-10-03 | 48 | 25% | 3.75d | 0.5d | 0d |
| 62 | 1.2.7.2.1.4 | Deliberate policy issues |  | 20d | 2019-10-03 | 2019-10-31 | 61 |  |  | 0.5d |  |
| 63 | 1.2.7.2.1.5 | Develop draft work product |  | 30d | 2019-10-03 | 2019-11-12 | 61 |  |  | 230.5d | 0d |
| 64 | 1.2.7.2.1.6 | Conduct First Reading + verbal and email response |  | 10d | 2019-10-03 | 2019-10-17 | 61 |  |  | 250.5d | 20d |
| 65 | 1.2.7.2.1.7 | Conduct Second Reading + verbal response + adoption or discard |  | 5d | 2019-11-12 | 2019-11-19 | 63, 64 |  |  | 230.5d |  |

| ID | WBS | Task | Duration | Start | Finish | Predecessors | Complete | Remaining | Total slack | Free slack |
| --- | --- | --- | --- | --- | --- | --- | --- | --- | --- | --- |
| 66 | 1.2.7.2.2 | **Accreditation and Authentication (Credentialing)** | 55d | 2019-09-06 A | 2019-11-19 |  | 27% | 40.2d | 230d |  |
| 67 | 1.2.7.2.2.1 | Understand topic and determine need to deliberate | 5d | 2019-09-06 A | 2019-09-12 A | 38 | 100% |  |  |  |
| 68 | 1.2.7.2.2.2 | Deliberate policy considerations and determine approach | 5d | 2019-09-06 A | 2019-09-12 A | 38 | 100% |  |  |  |
| 69 | 1.2.7.2.2.3 | Deliberate policy issues | 35d | 2019-09-13 A | 2019-10-31 | 68 | 25% | 26.25d | 0d |  |
| 70 | 1.2.7.2.2.4 | Develop draft work product | 45d | 2019-09-13 A | 2019-11-12 | 68 | 10% | 40.5d | 230d | 0d |
| 71 | 1.2.7.2.2.5 | Conduct First Reading + verbal and email response | 10d | 2019-09-13 A | 2019-09-26 | 68 | 50% | 5d | 265d | 35d |
| 72 | 1.2.7.2.2.6 | Conduct Second Reading + verbal response + adoption or discard | 5d | 2019-11-13 | 2019-11-19 | 70, 71 |  |  | 230d |  |
| 73 | 1.2.7.2.3 | **Lawful Basis & Balancing Test** | 55d | 2019-09-06 A | 2019-11-19 |  | 27% | 40.2d | 230d |  |
| 74 | 1.2.7.2.3.1 | Understand topic and determine need to deliberate | 5d | 2019-09-06 A | 2019-09-12 A | 38 | 100% |  |  |  |
| 75 | 1.2.7.2.3.2 | Deliberate policy considerations and determine approach | 5d | 2019-09-06 A | 2019-09-12 A | 38 | 100% |  |  |  |
| 76 | 1.2.7.2.3.3 | Deliberate policy issues | 35d | 2019-09-13 A | 2019-10-31 | 75 | 25% | 26.25d | 0d |  |
| 77 | 1.2.7.2.3.4 | Develop draft work product | 45d | 2019-09-13 A | 2019-11-12 | 75 | 10% | 40.5d | 230d | 0d |
| 78 | 1.2.7.2.3.5 | Conduct First Reading + verbal and email response | 10d | 2019-09-13 A | 2019-09-26 | 75 | 50% | 5d | 265d | 35d |
| 79 | 1.2.7.2.3.6 | Conduct Second Reading + verbal response + adoption or discard | 5d | 2019-11-13 | 2019-11-19 | 77, 78 |  |  | 230d |  |
| 80 | 1.2.7.2.4 | **Determine Process publication, format and content request requirements** | 55d | 2019-09-06 A | 2019-11-19 |  | 23% | 42.56d | 230d |  |
| 81 | 1.2.7.2.4.1 | Understand topic and determine need to deliberate | 5d | 2019-09-06 A | 2019-09-12 A | 38 | 100% |  |  |  |
| 82 | 1.2.7.2.4.2 | Deliberate policy considerations and determine approach | 5d | 2019-09-06 A | 2019-09-12 A | 38 | 100% |  |  |  |
| 83 | 1.2.7.2.4.3 | Deliberate policy issues | 35d | 2019-09-13 A | 2019-10-31 | 82 | 25% | 26.25d | 0d |  |
| 84 | 1.2.7.2.4.4 | Develop draft work product | 45d | 2019-09-13 | 2019-11-12 | 82 |  |  | 230d | 0d |
| 85 | 1.2.7.2.4.5 | Conduct First Reading + verbal and email response | 10d | 2019-09-13 A | 2019-09-26 | 82 | 50% | 5d | 265d | 35d |
| 86 | 1.2.7.2.4.6 | Conduct Second Reading + verbal response + adoption or discard | 5d | 2019-11-13 | 2019-11-19 | 84, 85 |  |  | 230d |  |
| 87 | 1.2.7.2.5 | **Timeline of process** | 55d | 2019-09-06 A | 2019-11-19 |  | 23% | 42.56d | 230d |  |
| 88 | 1.2.7.2.5.1 | Understand topic and determine need to deliberate | 5d | 2019-09-06 A | 2019-09-12 A | 38 | 100% |  |  |  |
| 89 | 1.2.7.2.5.2 | Deliberate policy considerations and determine approach | 5d | 2019-09-06 A | 2019-09-12 A | 38 | 100% |  |  |  |
| 90 | 1.2.7.2.5.3 | Deliberate policy issues | 35d | 2019-09-13 A | 2019-10-31 | 89 | 25% | 26.25d | 0d |  |
| 91 | 1.2.7.2.5.4 | Develop draft work product | 45d | 2019-09-13 | 2019-11-12 | 89 |  |  | 230d | 0d |
| 92 | 1.2.7.2.5.5 | Conduct First Reading + verbal and email response | 10d | 2019-09-13 A | 2019-09-26 | 89 | 50% | 5d | 265d | 35d |
| 93 | 1.2.7.2.5.6 | Conduct Second Reading + verbal response + adoption or discard | 5d | 2019-11-13 | 2019-11-19 | 91, 92 |  |  | 230d |  |

| ID | WBS | Task | Type | Duration | Start | Finish | Predecessors | Complete | Remaining | Total slack | Free slack |
| --- | --- | --- | --- | --- | --- | --- | --- | --- | --- | --- | --- |
| 94 | 1.2.7.2.6 | **Automation Analysis + Centralized vs. De-Centralized Models** |  | 55d | 2019-09-06 A | 2019-11-19 |  | 32% | 37.31d | 230d |  |
| 95 | 1.2.7.2.6.1 | Understand topic and determine need to deliberate |  | 5d | 2019-09-06 A | 2019-09-12 A | 38 | 100% |  |  |  |
| 96 | 1.2.7.2.6.2 | Deliberate policy considerations and determine approach |  | 5d | 2019-09-06 A | 2019-09-12 A | 38 | 100% |  |  |  |
| 97 | 1.2.7.2.6.3 | Deliberate policy issues |  | 35d | 2019-09-13 A | 2019-10-31 | 96 | 50% | 17.5d | 0d |  |
| 98 | 1.2.7.2.6.4 | Determine if automation is consistent with legal requirements/legal basis |  | 45d | 2019-09-13 A | 2019-11-12 | 96 | 25% | 33.75d | 235d |  |
| 99 | 1.2.7.2.6.5 | Develop draft work product |  | 45d | 2019-09-13 A | 2019-11-12 | 96 | 10% | 40.5d | 230d | 0d |
| 100 | 1.2.7.2.6.6 | Conduct First Reading + verbal and email response |  | 10d | 2019-09-13 A | 2019-09-26 | 96 | 50% | 5d | 265d | 35d |
| 101 | 1.2.7.2.6.7 | Conduct Second Reading + verbal response + adoption or discard |  | 5d | 2019-11-13 | 2019-11-19 | 99, 100 |  |  | 230d |  |
| 102 | 1.2.7.2.7 | **Review possible comprehensive model and options** |  | 55d | 2019-09-06 A | 2019-11-19 |  | 35% | 35.62d | 230d |  |
| 103 | 1.2.7.2.7.1 | Understand topic and determine need to deliberate |  | 5d | 2019-09-06 A | 2019-09-12 A | 38 | 100% |  |  |  |
| 104 | 1.2.7.2.7.2 | Deliberate policy considerations and determine approach |  | 5d | 2019-09-06 A | 2019-09-12 A | 38 | 100% |  |  |  |
| 105 | 1.2.7.2.7.3 | Deliberate policy issues |  | 35d | 2019-09-13 A | 2019-10-31 | 104 | 50% | 17.5d | 0d |  |
| 106 | 1.2.7.2.7.4 | Develop draft work product |  | 45d | 2019-09-13 A | 2019-11-12 | 104 | 10% | 40.5d | 230d | 0d |
| 107 | 1.2.7.2.7.5 | Conduct First Reading + verbal and email response |  | 10d | 2019-09-13 A | 2019-09-26 | 104 | 50% | 5d | 265d | 35d |
| 108 | 1.2.7.2.7.6 | Conduct Second Reading + verbal response + adoption or discard |  | 5d | 2019-11-13 | 2019-11-19 | 106, 107 |  |  | 230d |  |
| 109 | 1.2.7.2.8 | **Financial sustainability** |  | 55d | 2019-09-06 A | 2019-11-19 |  | 35% | 35.62d | 230d |  |
| 110 | 1.2.7.2.8.1 | Understand topic and determine need to deliberate |  | 5d | 2019-09-06 A | 2019-09-12 A | 38 | 100% |  |  |  |
| 111 | 1.2.7.2.8.2 | Deliberate policy considerations and determine approach |  | 5d | 2019-09-06 A | 2019-09-12 A | 38 | 100% |  |  |  |
| 112 | 1.2.7.2.8.3 | Deliberate policy issues |  | 35d | 2019-09-13 A | 2019-10-31 | 111 | 50% | 17.5d | 0d |  |
| 113 | 1.2.7.2.8.4 | Develop draft work product |  | 45d | 2019-09-13 A | 2019-11-12 | 111 | 10% | 40.5d | 230d | 0d |
| 114 | 1.2.7.2.8.5 | Conduct First Reading + verbal and email response |  | 10d | 2019-09-13 A | 2019-09-26 | 111 | 50% | 5d | 265d | 35d |
| 115 | 1.2.7.2.8.6 | Conduct Second Reading + verbal response + adoption or discard |  | 5d | 2019-11-13 | 2019-11-19 | 113, 114 |  |  | 230d |  |
| 116 | 1.2.7.2.9 | **Purpose 2 Rework per Phase 1 and Board Instruction to GNSO Council** |  | 55d | 2019-09-06 A | 2019-11-19 | 35 | 23% | 42.56d | 230d |  |
| 117 | 1.2.7.2.9.1 | Understand topic and determine need to deliberate |  | 5d | 2019-09-06 A | 2019-09-12 A | 38 | 100% |  |  |  |
| 118 | 1.2.7.2.9.2 | Deliberate policy considerations and determine approach |  | 5d | 2019-09-06 A | 2019-09-12 A | 38 | 100% |  |  |  |
| 119 | 1.2.7.2.9.3 | Deliberate policy issues |  | 35d | 2019-09-13 A | 2019-10-31 | 118 | 25% | 26.25d | 0d |  |
| 120 | 1.2.7.2.9.4 | Develop draft work product |  | 45d | 2019-09-13 | 2019-11-12 | 118 |  |  | 230d | 0d |
| 121 | 1.2.7.2.9.5 | Conduct First Reading + verbal and email response |  | 10d | 2019-09-13 A | 2019-09-26 | 118 | 50% | 5d | 265d | 35d |
| 122 | 1.2.7.2.9.6 | Conduct Second Reading + verbal response + adoption or discard |  | 5d | 2019-11-13 | 2019-11-19 | 120, 121 |  |  | 230d |  |
| 123 | 1.2.7.3 | Priority 1 draft zero documents for LA1 F2F2 | milestone | 0d | 2019-09-05 A | 2019-09-05 A | 35 | 100% |  |  |  |
| 124 | 1.2.7.4 | Priority 1 draft 1.0 documents for ICANN66 Montreal | milestone | 0d | 2019-10-31 | 2019-10-31 | 62, 69, 76, 83, 90, 97, 105, 112, 119 |  |  | 0d |  |

| ID | WBS | Task | Duration | Start | Finish | Predecessors | Complete | Remaining | Total slack | Free slack |
| --- | --- | --- | --- | --- | --- | --- | --- | --- | --- | --- |
| 125 | 1.2.8 | **Priority 2 Deliberations (Issues carried from Phase 1)** | 237d | 2019-05-31 A | 2020-04-23 |  | 2% | 233.42d | 118d |  |
| 126 | 1.2.8.1 | Organize Priority 2 topics | 1d | 2019-05-31 A | 2019-05-31 A | 26 | 100% |  |  |  |
| 127 | 1.2.8.2 | **Display of information of affiliated vs. accredited privacy / proxy providers** | 230d | 2019-06-03 A | 2020-04-15 |  | 1% | 227.44d | 124d |  |
| 128 | 1.2.8.2.1 | Initial Scoping of topic | 5d | 2019-06-03 A | 2019-06-07 A | 126 | 100% |  |  |  |
| 129 | 1.2.8.2.2 | **Understand topic and determine need to deliberate** | 110d | 2019-06-10 | 2019-11-06 |  |  |  | 124d | 0d |
| 130 | 1.2.8.2.2.1 | PPSAI IRT briefing to determine how their work compliments or depends on EPDP | 110d | 2019-06-10 | 2019-11-06 | 128 |  |  | 124d |  |
| 131 | 1.2.8.2.2.2 | Determine if briefing regarding a data privacy impact assessment on the PPSAI program is required | 110d | 2019-06-10 | 2019-11-06 | 128 |  |  | 124d |  |
| 132 | 1.2.8.2.2.3 | Determine if answers to legal questions are required | 110d | 2019-06-10 | 2019-11-06 | 128 |  |  | 124d |  |
| 133 | 1.2.8.2.3 | Deliberate policy considerations and determine approach | 5d | 2019-11-07 | 2019-11-13 | 129 |  |  | 124d | 0d |
| 134 | 1.2.8.2.4 | Deliberate policy issues | 90d | 2019-11-14 | 2020-03-18 | 133 |  |  | 124d | 0d |
| 135 | 1.2.8.2.5 | Develop draft work product | 10d | 2020-03-19 | 2020-04-01 | 134 |  |  | 124d | 0d |
| 136 | 1.2.8.2.6 | Conduct First Reading + verbal and email response | 5d | 2020-04-02 | 2020-04-08 | 135 |  |  | 124d | 0d |
| 137 | 1.2.8.2.7 | Conduct Second Reading + verbal response + adoption or discard | 5d | 2020-04-09 | 2020-04-15 | 136 |  |  | 124d |  |
| 138 | 1.2.8.3 | **Legal vs. Natural** | 230d | 2019-06-03 A | 2020-04-15 |  | 1% | 227.95d | 124d |  |
| 139 | 1.2.8.3.1 | Initial Scoping of topic | 5d | 2019-06-03 A | 2019-06-07 A | 126 | 100% |  |  |  |
| 140 | 1.2.8.3.2 | **Understand topic and determine need to deliberate** | 110d | 2019-06-10 | 2019-11-06 |  |  |  | 124d | 0d |
| 141 | 1.2.8.3.2.1 | Receive briefing from Bird & Bird on legal vs. natural memo | 110d | 2019-06-10 | 2019-11-06 | 139 |  |  | 124d |  |
| 142 | 1.2.8.3.2.2 | Determine if answers to legal questions are required | 110d | 2019-06-10 | 2019-11-06 | 139 |  |  | 124d |  |
| 143 | 1.2.8.3.2.3 | EPDP Team to confirm with ICANN Org expected next steps and timing to conduct and publish the study results. | 110d | 2019-06-10 | 2019-11-06 | 139 |  |  | 124d |  |
| 144 | 1.2.8.3.2.4 | EPDP Team or Sub-team to work with ICANN org on this study, including providing questions and/or relevant background to assist in informing the study by 1 July 2019. | 110d | 2019-06-10 | 2019-11-06 | 139 |  |  | 124d |  |
| 145 | 1.2.8.3.3 | Deliberate policy considerations and determine approach | 5d | 2019-11-07 | 2019-11-13 | 140 |  |  | 124d | 0d |
| 146 | 1.2.8.3.4 | Deliberate policy issues | 90d | 2019-11-14 | 2020-03-18 | 145 |  |  | 124d | 0d |
| 147 | 1.2.8.3.5 | Develop draft work product | 10d | 2020-03-19 | 2020-04-01 | 146 |  |  | 124d | 0d |
| 148 | 1.2.8.3.6 | Conduct First Reading + verbal and email response | 5d | 2020-04-02 | 2020-04-08 | 147 |  |  | 124d | 0d |
| 149 | 1.2.8.3.7 | Conduct Second Reading + verbal response + adoption or discard | 5d | 2020-04-09 | 2020-04-15 | 148 |  |  | 124d |  |

| ID | WBS | Task | Duration | Start | Finish | Predecessors | Complete | Remaining | Total slack | Free slack | Constraint |
| --- | --- | --- | --- | --- | --- | --- | --- | --- | --- | --- | --- |
| 150 | 1.2.8.4 | **City Field** | 230d | 2019-06-11 A | 2020-04-23 |  | 2% | 226.29d | 118d |  |  |
| 151 | 1.2.8.4.1 | Initial Scoping of topic | 5d | 2019-06-11 A | 2019-06-17 A | 126 | 100% |  |  |  | start no earlier than 2019-06-11 |
| 152 | 1.2.8.4.2 | **Understand topic and determine need to deliberate** | 110d | 2019-06-18 | 2019-11-14 |  |  |  | 118d | 0d |  |
| 153 | 1.2.8.4.2.1 | Receive briefing from Bird & Bird on city field memo | 110d | 2019-06-18 | 2019-11-14 | 151 |  |  | 118d |  |  |
| 154 | 1.2.8.4.2.2 | Determine if answers to legal questions are required | 80d | 2019-06-18 | 2019-10-07 | 151 |  |  | 148d |  |  |
| 155 | 1.2.8.4.3 | Deliberate policy considerations and determine approach | 5d | 2019-11-15 | 2019-11-21 | 152 |  |  | 118d | 0d | start no earlier than 2019-06-11 |
| 156 | 1.2.8.4.4 | Deliberate policy issues | 90d | 2019-11-22 | 2020-03-26 | 155 |  |  | 118d | 0d |  |
| 157 | 1.2.8.4.5 | Develop draft work product | 10d | 2020-03-27 | 2020-04-09 | 156 |  |  | 118d | 0d |  |
| 158 | 1.2.8.4.6 | Conduct First Reading + verbal and email response | 5d | 2020-04-10 | 2020-04-16 | 157 |  |  | 118d | 0d |  |
| 159 | 1.2.8.4.7 | Conduct Second Reading + verbal response + adoption or discard | 5d | 2020-04-17 | 2020-04-23 | 158 |  |  | 118d |  |  |
| 160 | 1.2.8.5 | **Data Retention** | 230d | 2019-06-11 A | 2020-04-23 |  | 2% | 225d | 118d |  |  |
| 161 | 1.2.8.5.1 | Initial Scoping of topic | 5d | 2019-06-11 A | 2019-06-17 A | 126 | 100% |  |  |  | start no earlier than 2019-06-11 |
| 162 | 1.2.8.5.2 | **Understand topic and determine need to deliberate** | 110d | 2019-06-18 | 2019-11-14 |  |  |  | 118d | 0d |  |
| 163 | 1.2.8.5.2.1 | Confirm with ICANN org when the review of all of ICANN org's processes and procedures to identify and document the instances in which personal data is requested beyond the life of domain name registration is expected to be completed. | 110d | 2019-06-18 | 2019-11-14 | 161 |  |  | 118d |  |  |
| 164 | 1.2.8.5.3 | Deliberate policy considerations and determine approach | 5d | 2019-11-15 | 2019-11-21 | 162 |  |  | 118d | 0d | start no earlier than 2019-06-11 |
| 165 | 1.2.8.5.4 | **Deliberate policy issues** | 90d | 2019-11-22 | 2020-03-26 |  |  |  | 118d | 0d |  |
| 166 | 1.2.8.5.4.1 | Confirm whether the data retention requirements recommended in phase 1 are to be confirmed or whether updates are needed | 90d | 2019-11-22 | 2020-03-26 | 164 |  |  | 118d |  |  |
| 167 | 1.2.8.5.5 | Develop draft work product | 10d | 2020-03-27 | 2020-04-09 | 165 |  |  | 118d | 0d |  |
| 168 | 1.2.8.5.6 | Conduct First Reading + verbal and email response | 5d | 2020-04-10 | 2020-04-16 | 167 |  |  | 118d | 0d |  |
| 169 | 1.2.8.5.7 | Conduct Second Reading + verbal response + adoption or discard | 5d | 2020-04-17 | 2020-04-23 | 168 |  |  | 118d |  |  |
| 170 | 1.2.8.6 | **Additional purpose for ICANN’s OCTO** | 220d | 2019-06-17 A | 2020-04-15 |  | 2% | 216.56d | 124d |  |  |
| 171 | 1.2.8.6.1 | Initial Scoping of topic | 5d | 2019-06-17 A | 2019-06-21 A | 126 | 100% |  |  |  | start no earlier than 2019-06-17 |
| 172 | 1.2.8.6.2 | **Understand topic and determine need to deliberate** | 100d | 2019-06-24 | 2019-11-06 |  |  |  | 124d | 0d |  |
| 173 | 1.2.8.6.2.1 | Further to EPDP-P1 Rec#2, EPDP Team to draft question to ICANN org, to inform next steps. | 100d | 2019-06-24 | 2019-11-06 | 171 |  |  | 124d |  |  |
| 174 | 1.2.8.6.2.2 | Determine if answers to legal questions are required | 100d | 2019-06-24 | 2019-11-06 | 171 |  |  | 124d |  |  |
| 175 | 1.2.8.6.3 | Deliberate policy considerations and determine approach | 5d | 2019-11-07 | 2019-11-13 | 172 |  |  | 124d | 0d | start no earlier than 2019-06-17 |
| 176 | 1.2.8.6.4 | Deliberate policy issues | 90d | 2019-11-14 | 2020-03-18 | 175 |  |  | 124d | 0d |  |
| 177 | 1.2.8.6.5 | Develop draft work product | 10d | 2020-03-19 | 2020-04-01 | 176 |  |  | 124d | 0d |  |
| 178 | 1.2.8.6.6 | Conduct First Reading + verbal and email response | 5d | 2020-04-02 | 2020-04-08 | 177 |  |  | 124d | 0d |  |
| 179 | 1.2.8.6.7 | Conduct Second Reading + verbal response + adoption or discard | 5d | 2020-04-09 | 2020-04-15 | 178 |  |  | 124d |  |  |

| ID | WBS | Task | Duration | Start | Finish | Predecessors | Complete | Remaining | Total slack | Free slack | Constraint |
| --- | --- | --- | --- | --- | --- | --- | --- | --- | --- | --- | --- |
| 180 | 1.2.8.7 | **Feasibility of unique contacts to have uniform anonymized email address** | 210d | 2019-06-17 A | 2020-04-01 |  | 2% | 205d | 134d |  |  |
| 181 | 1.2.8.7.1 | Initial Scoping of topic | 5d | 2019-06-17 A | 2019-06-21 A | 126 | 100% |  |  |  | start no earlier than 2019-06-17 |
| 182 | 1.2.8.7.2 | **Understand topic and determine need to deliberate** | 90d | 2019-06-24 | 2019-10-25 |  |  |  | 134d | 0d |  |
| 183 | 1.2.8.7.2.1 | Determine if answers to legal questions are required | 90d | 2019-06-24 | 2019-10-25 | 181 |  |  | 134d |  |  |
| 184 | 1.2.8.7.3 | Deliberate policy considerations and determine approach | 5d | 2019-10-28 | 2019-11-01 | 182 |  |  | 134d | 0d | start no earlier than 2019-06-17 |
| 185 | 1.2.8.7.4 | Deliberate policy issues | 90d | 2019-11-02 | 2020-03-04 | 184 |  |  | 134d | 0d |  |
| 186 | 1.2.8.7.5 | Develop draft work product | 10d | 2020-03-05 | 2020-03-18 | 185 |  |  | 134d | 0d |  |
| 187 | 1.2.8.7.6 | Conduct First Reading + verbal and email response | 5d | 2020-03-19 | 2020-03-25 | 186 |  |  | 134d | 0d |  |
| 188 | 1.2.8.7.7 | Conduct Second Reading + verbal response + adoption or discard | 5d | 2020-03-26 | 2020-04-01 | 187 |  |  | 134d |  |  |
| 189 | 1.2.8.8 | **Data Accuracy and the WHOIS Accuracy Reporting System** | 210d | 2019-07-09 A | 2020-04-23 |  | 2% | 206.5d | 118d |  |  |
| 190 | 1.2.8.8.1 | Initial Scoping of topic | 5d | 2019-07-09 A | 2019-07-15 A | 126 | 100% |  |  |  | start no earlier than 2019-07-09 |
| 191 | 1.2.8.8.2 | **Understand topic and determine need to deliberate** | 90d | 2019-07-16 | 2019-11-14 |  |  |  | 118d | 0d |  |
| 192 | 1.2.8.8.2.1 | Receive briefing from Bird & Bird on city field memo | 90d | 2019-07-16 | 2019-11-14 | 190 |  |  | 118d |  |  |
| 193 | 1.2.8.8.2.2 | Determine if answers to legal questions are required | 90d | 2019-07-16 | 2019-11-14 | 190 |  |  | 118d |  |  |
| 194 | 1.2.8.8.3 | Deliberate policy considerations and determine approach | 5d | 2019-11-15 | 2019-11-21 | 191 |  |  | 118d | 0d | start no earlier than 2019-07-09 |
| 195 | 1.2.8.8.4 | Deliberate policy issues | 90d | 2019-11-22 | 2020-03-26 | 194 |  |  | 118d | 0d |  |
| 196 | 1.2.8.8.5 | Develop draft work product | 10d | 2020-03-27 | 2020-04-09 | 195 |  |  | 118d | 0d |  |
| 197 | 1.2.8.8.6 | Conduct First Reading + verbal and email response | 5d | 2020-04-10 | 2020-04-16 | 196 |  |  | 118d | 0d |  |
| 198 | 1.2.8.8.7 | Conduct Second Reading + verbal response + adoption or discard | 5d | 2020-04-17 | 2020-04-23 | 197 |  |  | 118d |  |  |
| 199 | 1.2.9 | **Unplanned Issues & Tasks** | 80d | 2019-12-04 | 2020-03-24 |  |  |  | 140d |  |  |
| 200 | 1.2.9.1 | **Phase 2 discussion on Geographic Basis** | 80d | 2019-12-04 | 2020-03-24 |  |  |  | 140d |  |  |
| 201 | 1.2.9.1.1 | Understand topic and determine need to deliberate | 5d | 2019-12-04 | 2019-12-10 | 309 |  |  | 140d | 0d | start no earlier than 2019-08-22 |
| 202 | 1.2.9.1.2 | Deliberate policy considerations and determine approach | 5d | 2019-12-11 | 2019-12-17 | 201 |  |  | 140d | 0d | start no earlier than 2019-08-22 |
| 203 | 1.2.9.1.3 | Deliberate policy issues | 60d | 2019-12-18 | 2020-03-10 | 202 |  |  | 150d |  |  |
| 204 | 1.2.9.1.4 | Develop draft work product | 60d | 2019-12-18 | 2020-03-10 | 202 |  |  | 140d | 0d |  |
| 205 | 1.2.9.1.5 | Conduct First Reading + verbal and email response | 5d | 2020-03-11 | 2020-03-17 | 204 |  |  | 140d | 0d |  |
| 206 | 1.2.9.1.6 | Conduct Second Reading + verbal response + adoption or discard | 5d | 2020-03-18 | 2020-03-24 | 205 |  |  | 140d |  |  |

| ID | WBS | Task | Type | Duration | Start | Finish | Predecessors | Complete | Remaining | Total slack | Free slack | Constraint |
| --- | --- | --- | --- | --- | --- | --- | --- | --- | --- | --- | --- | --- |
| 207 | 1.2.9.2 | **Phase 2 discussion on Thick Whois coming from IRT>Board>Council>EPDP2>Council>Board** |  | 80d | 2019-12-04 | 2020-03-24 |  |  |  | 140d |  |  |
| 208 | 1.2.9.2.1 | Understand topic and determine need to deliberate |  | 5d | 2019-12-04 | 2019-12-10 | 309 |  |  | 140d | 0d | start no earlier than 2019-08-22 |
| 209 | 1.2.9.2.2 | Deliberate policy considerations and determine approach |  | 5d | 2019-12-11 | 2019-12-17 | 208 |  |  | 140d | 0d | start no earlier than 2019-08-22 |
| 210 | 1.2.9.2.3 | Deliberate policy issues |  | 60d | 2019-12-18 | 2020-03-10 | 209 |  |  | 150d |  |  |
| 211 | 1.2.9.2.4 | Develop draft work product |  | 60d | 2019-12-18 | 2020-03-10 | 209 |  |  | 140d | 0d |  |
| 212 | 1.2.9.2.5 | Conduct First Reading + verbal and email response |  | 5d | 2020-03-11 | 2020-03-17 | 211 |  |  | 140d | 0d |  |
| 213 | 1.2.9.2.6 | Conduct Second Reading + verbal response + adoption or discard |  | 5d | 2020-03-18 | 2020-03-24 | 212 |  |  | 140d |  |  |
| 214 | 1.2.10 | **Legal Sub team** |  | 133d | 2019-05-30 A | 2019-11-28 |  | 70% | 40.06d | 123d |  |  |
| 215 | 1.2.10.1 | Establish operating framework for handling legal advice requirements |  | 33d | 2019-05-30 A | 2019-07-15 A |  | 100% |  |  |  | start no earlier than 2019-05-30 |
| 216 | 1.2.10.2 | Select members and establish chair |  | 33d | 2019-05-30 A | 2019-07-15 A |  | 100% |  |  |  | start no earlier than 2019-05-30 |
| 217 | 1.2.10.3 | On-going review of legal questions / advice and interaction with counsel for Initial Report |  | 100d | 2019-07-16 A | 2019-11-28 | 215 | 50% | 50d | 123d | 0d |  |
| 218 | 1.2.11 | **Key Events** |  | 310d | 2019-04-03 A | 2020-06-05 |  | 42% | 179.95d | 87d |  |  |
| 219 | 1.2.11.1 | **EPDP Team F2F Meeting - Marrakech (24-27 Jun 2019)** |  | 111d | 2019-04-03 A | 2019-09-04 A |  | 100% |  |  |  |  |
| 220 | 1.2.11.1.1 | Determine requirements and scope |  | 1d | 2019-04-03 A | 2019-04-03 A | 18 | 100% |  |  |  |  |
| 221 | 1.2.11.1.2 | Obtain PCST approval |  | 10d | 2019-04-04 A | 2019-04-17 A | 220 | 100% |  |  |  |  |
| 222 | 1.2.11.1.3 | Interact with Meetings Team |  | 75d | 2019-04-18 A | 2019-07-31 A | 221 | 100% |  |  |  |  |
| 223 | 1.2.11.1.4 | Engage EPDP team to confirm RSVPs and manage applications for travel support |  | 30d | 2019-04-18 A | 2019-05-29 A | 221 | 100% |  |  |  |  |
| 224 | 1.2.11.1.5 | Engage facilitators - not required | milestone | 0d | 2019-04-17 A | 2019-04-17 A | 221 | 100% |  |  |  |  |
| 225 | 1.2.11.1.6 | Plan agenda |  | 45d | 2019-04-18 A | 2019-06-19 A | 221 | 100% |  |  |  |  |
| 226 | 1.2.11.1.7 | Confirm Day 0 work products (see tasks above) | milestone | 0d | 2019-06-13 A | 2019-06-13 A | 221, 38 | 100% |  |  |  |  |
| 227 | 1.2.11.1.8 | Day 0 preparations |  | 1d | 2019-06-21 A | 2019-06-21 A | 225 | 100% |  |  |  | start no earlier than 2019-06-21 |
| 228 | 1.2.11.1.9 | Day 1 sessions |  | 1d | 2019-06-25 A | 2019-06-25 A | 227 | 100% |  |  |  | start no earlier than 2019-06-25 |
| 229 | 1.2.11.1.10 | Day 2 sessions |  | 1d | 2019-06-27 A | 2019-06-27 A | 228 | 100% |  |  |  | start no earlier than 2019-06-27 |
| 230 | 1.2.11.1.11 | F2F Recon and Sitrep | milestone | 0d | 2019-06-27 A | 2019-06-27 A | 229 | 100% |  |  |  |  |
| 231 | 1.2.11.1.12 | Communicate outcomes |  | 10d | 2019-06-28 A | 2019-07-11 A | 230 | 100% |  |  |  |  |
| 232 | 1.2.11.1.13 | Manage financial invoice, payment confirmation, and tracking (report to PCST) |  | 100d | 2019-04-18 A | 2019-09-04 A | 221 | 100% |  |  |  |  |
| 233 | 1.2.11.1.14 | Close F2F | milestone | 0d | 2019-09-04 A | 2019-09-04 A | 232 | 100% |  |  |  |  |

| ID | WBS | Task | Type | Duration | Start | Finish | Predecessors | Complete | Remaining | Total slack | Free slack | Constraint |
| --- | --- | --- | --- | --- | --- | --- | --- | --- | --- | --- | --- | --- |
| 234 | 1.2.11.2 | **EPDP Team F2F Meeting - Los Angeles (08-11 Sept 2019)** |  | 131d | 2019-05-30 A | 2019-11-26 |  | 86% | 18.94d | 225d |  |  |
| 235 | 1.2.11.2.1 | Determine requirements and scope |  | 1d | 2019-05-30 A | 2019-05-30 A | 19 | 100% |  |  |  |  |
| 236 | 1.2.11.2.2 | Obtain PCST approval |  | 20d | 2019-05-31 A | 2019-06-27 A | 235 | 100% |  |  |  |  |
| 237 | 1.2.11.2.3 | Interact with Meetings Team |  | 100d | 2019-06-07 A | 2019-10-24 | 236 | 75% | 25d | 250d |  |  |
| 238 | 1.2.11.2.4 | Evaluate locations and reserve hotel and facilities |  | 25d | 2019-06-07 A | 2019-07-11 A | 236 | 100% |  |  |  |  |
| 239 | 1.2.11.2.5 | Engage EPDP team to confirm RSVPs and manage applications for travel support |  | 30d | 2019-07-12 A | 2019-08-22 A | 238 | 100% |  |  |  |  |
| 240 | 1.2.11.2.6 | Engage hotel and facilities support teams |  | 70d | 2019-07-12 A | 2019-10-17 | 238 | 85% | 10.5d | 255d |  |  |
| 241 | 1.2.11.2.7 | Research and schedule events as necessary |  | 45d | 2019-07-12 A | 2019-09-12 A | 238 | 100% |  |  |  |  |
| 242 | 1.2.11.2.8 | Engage facilitators |  | 75d | 2019-06-07 A | 2019-09-19 A | 236 | 100% |  |  |  |  |
| 243 | 1.2.11.2.9 | Plan agenda |  | 60d | 2019-06-07 A | 2019-09-11 A | 236 | 100% |  |  |  |  |
| 244 | 1.2.11.2.10 | Confirm draft zero work products (see tasks above) | milestone | 0d | 2019-09-05 A | 2019-09-05 A | 236, 123 | 100% |  |  |  |  |
| 245 | 1.2.11.2.11 | Day 0 preparations | manual | 1d | 2019-09-08 A | 2019-09-08 A | 243 | 100% |  |  |  |  |
| 246 | 1.2.11.2.12 | Day 1 sessions |  | 1d | 2019-09-09 A | 2019-09-09 A | 245 | 100% |  |  |  |  |
| 247 | 1.2.11.2.13 | Day 2 sessions |  | 1d | 2019-09-10 A | 2019-09-10 A | 246 | 100% |  |  |  |  |
| 248 | 1.2.11.2.14 | Day 3 sessions |  | 1d | 2019-09-11 A | 2019-09-11 A | 247 | 100% |  |  |  |  |
| 249 | 1.2.11.2.15 | F2F Recon and Sitrep | milestone | 0d | 2019-09-11 A | 2019-09-11 A | 248 | 100% |  |  |  |  |
| 250 | 1.2.11.2.16 | Communicate outcomes |  | 10d | 2019-09-12 A | 2019-09-25 A | 249 | 100% |  |  |  |  |
| 251 | 1.2.11.2.17 | Manage financial invoice, payment confirmation, and tracking (report to PCST) |  | 110d | 2019-06-28 A | 2019-11-26 | 236 | 60% | 44d | 225d | 0d |  |
| 252 | 1.2.11.2.18 | Close F2F | milestone | 0d | 2019-11-26 | 2019-11-26 | 251 |  |  | 225d |  |  |
| 253 | 1.2.11.3 | **EPDP Team F2F Meeting - Montreal (02-07 Nov 2019)** |  | 106d | 2019-08-23 A | 2020-01-15 |  | 23% | 82.01d | 189d |  |  |
| 254 | 1.2.11.3.1 | Determine requirements and scope |  | 1d | 2019-08-23 A | 2019-08-23 A | 13 | 100% |  |  |  |  |
| 255 | 1.2.11.3.2 | Obtain PCST approval |  | 5d | 2019-08-26 A | 2019-08-30 A | 254 | 100% |  |  |  |  |
| 256 | 1.2.11.3.3 | Interact with Meetings Team |  | 75d | 2019-09-02 A | 2019-12-11 | 255 | 15% | 63.75d | 214d |  |  |
| 257 | 1.2.11.3.4 | Engage EPDP team to confirm RSVPs and manage applications for travel support |  | 30d | 2019-09-02 A | 2019-10-11 | 255 | 75% | 7.5d | 259d |  |  |
| 258 | 1.2.11.3.5 | Engage facilitators | milestone | 0d | 2019-08-30 A | 2019-08-30 | 255 | 10% | 0d | 289d |  |  |
| 259 | 1.2.11.3.6 | Plan agenda |  | 40d | 2019-09-02 A | 2019-10-25 | 255 | 50% | 20d | 91d | 4d |  |
| 260 | 1.2.11.3.7 | Confirm 1.0 draft work products (see tasks above) | milestone | 0d | 2019-10-31 | 2019-10-31 | 255, 124 |  |  | 245d |  |  |
| 261 | 1.2.11.3.8 | Day 0 preparations |  | 1d | 2019-11-01 | 2019-11-01 | 259 |  |  | 87d | 0d | start no earlier than 2019-11-01 |
| 262 | 1.2.11.3.9 | Day 1 sessions |  | 1d | 2019-11-02 | 2019-11-02 | 261 |  |  | 87d | 0d | start no earlier than 2019-11-02 |
| 263 | 1.2.11.3.10 | Day 2 sessions |  | 1d | 2019-11-03 | 2019-11-03 | 262 |  |  | 87d | 0d | start no earlier than 2019-11-03 |
| 264 | 1.2.11.3.11 | F2F Recon and Sitrep | milestone | 0d | 2019-11-03 | 2019-11-03 | 263 |  |  | 87d | 0d |  |
| 265 | 1.2.11.3.12 | Communicate outcomes |  | 10d | 2019-11-04 | 2019-11-15 | 264 |  |  | 232d |  |  |
| 266 | 1.2.11.3.13 | Manage financial invoice, payment confirmation, and tracking (report to PCST) |  | 100d | 2019-09-02 | 2020-01-15 | 255 |  |  | 189d | 0d |  |
| 267 | 1.2.11.3.14 | Close F2F | milestone | 0d | 2020-01-15 | 2020-01-15 | 266 |  |  | 189d |  |  |

| ID | WBS | Task | Type | Duration | Start | Finish | Predecessors | Complete | Remaining | Total slack | Free slack | Constraint |
| --- | --- | --- | --- | --- | --- | --- | --- | --- | --- | --- | --- | --- |
| 268 | 1.2.11.4 | **EPDP Team F2F Meeting - TBD [Los Angeles] (End of Jan 2020)** |  | 135d | 2019-09-24 A | 2020-03-26 |  | 7% | 125.42d | 138d |  |  |
| 269 | 1.2.11.4.1 | Determine requirements and scope |  | 1d | 2019-09-24 A | 2019-09-24 A | 20 | 100% |  |  |  |  |
| 270 | 1.2.11.4.2 | Obtain PCST approval |  | 5d | 2019-09-24 A | 2019-09-30 A | 20 | 100% |  |  |  |  |
| 271 | 1.2.11.4.3 | Interact with Meetings Team |  | 100d | 2019-10-01 A | 2020-02-13 | 270 | 5% | 95d | 168d |  |  |
| 272 | 1.2.11.4.4 | Evaluate locations and reserve hotel and facilities |  | 30d | 2019-10-01 A | 2019-11-07 A | 270 | 100% |  |  |  |  |
| 273 | 1.2.11.4.5 | Engage EPDP team to confirm RSVPs and manage applications for travel support |  | 30d | 2019-11-08 A | 2019-12-19 | 272 | 10% | 27d | 208d |  |  |
| 274 | 1.2.11.4.6 | Engage hotel and facilities support teams |  | 90d | 2019-11-08 | 2020-03-12 | 272 |  |  | 148d |  |  |
| 275 | 1.2.11.4.7 | Research and schedule events as necessary |  | 50d | 2019-11-08 | 2020-01-16 | 272 |  |  | 188d |  |  |
| 276 | 1.2.11.4.8 | Engage facilitators |  | 90d | 2019-10-01 | 2020-01-30 | 270 |  |  | 178d |  |  |
| 277 | 1.2.11.4.9 | Plan agenda |  | 80d | 2019-10-01 | 2020-01-16 | 270 |  |  | 174d | 6d |  |
| 278 | 1.2.11.4.10 | Confirm Day 0 work products (see tasks above) | milestone | 0d | 2020-01-21 | 2020-01-21 | 270, 310 |  |  | 185d |  |  |
| 279 | 1.2.11.4.11 | Day 0 preparations |  | 1d | 2020-01-27 | 2020-01-27 | 277 |  |  | 168d | 0d | start no earlier than 2020-01-27 |
| 280 | 1.2.11.4.12 | Day 1 sessions |  | 1d | 2020-01-28 | 2020-01-28 | 279 |  |  | 168d | 0d |  |
| 281 | 1.2.11.4.13 | Day 2 sessions |  | 1d | 2020-01-29 | 2020-01-29 | 280 |  |  | 168d | 0d |  |
| 282 | 1.2.11.4.14 | Day 3 sessions |  | 1d | 2020-01-30 | 2020-01-30 | 281 |  |  | 168d | 0d |  |
| 283 | 1.2.11.4.15 | F2F Recon and Sitrep | milestone | 0d | 2020-01-30 | 2020-01-30 | 282 |  |  | 168d | 0d |  |
| 284 | 1.2.11.4.16 | Communicate outcomes |  | 10d | 2020-01-31 | 2020-02-13 | 283 |  |  | 168d |  |  |
| 285 | 1.2.11.4.17 | Manage financial invoice, payment confirmation, and tracking (report to PCST) |  | 130d | 2019-10-01 | 2020-03-26 | 270 |  |  | 138d | 0d |  |
| 286 | 1.2.11.4.18 | Close F2F | milestone | 0d | 2020-03-26 | 2020-03-26 | 285 |  |  | 138d |  |  |
| 287 | 1.2.11.5 | **EPDP Team F2F Meeting - Cancun (07-12 Mar 2020)** |  | 155d | 2019-11-04 | 2020-06-05 |  |  |  | 87d |  |  |
| 288 | 1.2.11.5.1 | Determine requirements and scope |  | 1d | 2019-11-04 | 2019-11-04 | 264 |  |  | 241d |  |  |
| 289 | 1.2.11.5.2 | Obtain PCST approval |  | 5d | 2019-11-04 | 2019-11-08 | 264 |  |  | 87d | 0d |  |
| 290 | 1.2.11.5.3 | Interact with Meetings Team |  | 75d | 2019-11-11 | 2020-02-21 | 289 |  |  | 162d |  |  |
| 291 | 1.2.11.5.4 | Engage EPDP team to confirm RSVPs and manage applications for travel support |  | 30d | 2019-11-11 | 2019-12-20 | 289 |  |  | 207d |  |  |
| 292 | 1.2.11.5.5 | Engage facilitators | milestone | 0d | 2019-11-08 | 2019-11-08 | 289 |  |  | 237d |  |  |
| 293 | 1.2.11.5.6 | Plan agenda |  | 40d | 2019-11-11 | 2020-01-03 | 289 |  |  | 184d | 44d |  |
| 294 | 1.2.11.5.7 | Confirm Day 0 work products (see tasks above) | milestone | 0d | 2019-11-08 | 2019-11-08 | 289, 124 |  |  | 237d |  |  |
| 295 | 1.2.11.5.8 | Day 0 preparations |  | 1d | 2020-03-06 | 2020-03-06 | 293 |  |  | 140d | 0d | start no earlier than 2020-03-06 |
| 296 | 1.2.11.5.9 | Day 1 sessions |  | 1d | 2020-03-09 | 2020-03-09 | 295 |  |  | 140d | 0d | start no earlier than 2019-11-02 |
| 297 | 1.2.11.5.10 | Day 2 sessions |  | 1d | 2020-03-10 | 2020-03-10 | 296 |  |  | 140d | 0d | start no earlier than 2019-11-03 |
| 298 | 1.2.11.5.11 | F2F Recon and Sitrep | milestone | 0d | 2020-03-10 | 2020-03-10 | 297 |  |  | 140d | 0d |  |
| 299 | 1.2.11.5.12 | Communicate outcomes |  | 10d | 2020-03-11 | 2020-03-24 | 298 |  |  | 140d |  |  |
| 300 | 1.2.11.5.13 | Manage financial invoice, payment confirmation, and tracking (report to PCST) |  | 150d | 2019-11-11 | 2020-06-05 | 289 |  |  | 87d | 0d |  |
| 301 | 1.2.11.5.14 | Close F2F | milestone | 0d | 2020-06-05 | 2020-06-05 | 300 |  |  | 87d |  |  |

| ID | WBS | Task | Type | Duration | Start | Finish | Predecessors | Complete | Remaining | Total slack | Free slack |
| --- | --- | --- | --- | --- | --- | --- | --- | --- | --- | --- | --- |
| 302 | 1.3 | **INITIAL REPORT** |  | 150d | 2019-06-28 A | 2020-01-21 |  | 51% | 73.58d | 185d |  |
| 303 | 1.3.1 | Assemble initial conclusions |  | 90d | 2019-06-28 A | 2019-10-31 | 37 | 75% | 22.5d | 245d |  |
| 304 | 1.3.2 | Populate discussion papers with findings and potential recommendations |  | 90d | 2019-06-28 A | 2019-10-31 | 37 | 75% | 22.5d | 0d |  |
| 305 | 1.3.3 | Discuss/approve findings and interim recommendations |  | 10d | 2019-11-01 | 2019-11-12 | 124, 304 |  |  | 5d |  |
| 306 | 1.3.4 | Consolidate interim recommendations and findings |  | 15d | 2019-11-01 | 2019-11-19 | 124, 304 |  |  | 0d |  |
| 307 | 1.3.5 | Build Draft Report for public comment |  | 15d | 2019-11-01 | 2019-11-19 | 124, 304 |  |  | 0d |  |
| 308 | 1.3.6 | Approve Draft Report for public comment |  | 10d | 2019-11-20 | 2019-12-03 | 305, 306, 307 |  |  | 0d |  |
| 309 | 1.3.7 | Publish Initial Report | milestone | 0d | 2019-12-03 | 2019-12-03 | 308, 217 |  |  | 140d | 0d |
| 310 | 1.3.8 | Public comment forum on the Initial Report (49 days) |  | 35d | 2019-12-04 | 2020-01-21 | 308 |  |  | 0d |  |
| 311 | 1.4 | **FINAL REPORT** |  | 103d | 2019-11-29 | 2020-04-21 |  |  |  | 38d |  |
| 312 | 1.4.1 | Review of public comments |  | 25d | 2020-01-22 | 2020-02-25 | 310 |  |  | 0d |  |
| 313 | 1.4.2 | Continue deliberations of Priority 1 topics towards a Final Report |  | 40d | 2020-01-22 | 2020-03-17 | 310 |  |  | 145d |  |
| 314 | 1.4.3 | Continue deliberations of Priority 2 topics towards a Final Report |  | 40d | 2020-01-22 | 2020-03-17 | 310 |  |  | 145d |  |
| 315 | 1.4.4 | On-going review of legal questions / advice and interaction with counsel for Final Report |  | 100d | 2019-11-29 | 2020-04-16 | 217 |  |  | 123d |  |
| 316 | 1.4.5 | Build Final Report |  | 25d | 2020-02-26 | 2020-03-31 | 312 |  |  | 0d |  |
| 317 | 1.4.6 | Determine consensus levels on interim recommendations |  | 10d | 2020-04-01 | 2020-04-14 | 316 |  |  | 0d |  |
| 318 | 1.4.7 | Adopt final recommendations and report |  | 5d | 2020-04-15 | 2020-04-21 | 317 |  |  | 0d |  |
| 319 | 1.4.8 | Submission of Final Report to the GNSO Council | milestone | 0d | 2020-04-21 | 2020-04-21 | 318 |  |  | 0d |  |
| 320 | 1.5 | **POST EPDP ACTIVITIES** |  | 100d | 2020-04-22 | 2020-09-08 |  |  |  | 0d |  |
| 321 | 1.5.1 | Approval of Final Report and Recommendations by the GNSO Council |  | 40d | 2020-04-22 | 2020-06-16 | 319 |  |  | 0d |  |
| 322 | 1.5.2 | Report to the Board |  | 20d | 2020-06-17 | 2020-07-14 | 321 |  |  | 60d |  |
| 323 | 1.5.3 | Publish Recommendations for Public Comment |  | 35d | 2020-06-17 | 2020-08-04 | 321 |  |  | 0d |  |
| 324 | 1.5.4 | Inform GAC if Recommendations affect public policy |  | 35d | 2020-06-17 | 2020-08-04 | 321 |  |  | 45d |  |
| 325 | 1.5.5 | Board Paper |  | 20d | 2020-08-05 | 2020-09-01 | 323 |  |  | 0d |  |
| 326 | 1.5.6 | Board consideration / approval |  | 5d | 2020-09-02 | 2020-09-08 | 325 |  |  | 0d |  |
