# EPDP-P2_Project_Plan_20200531_baseline

Schedule from MS Project, 2019-03-04 to 2020-11-26, A marks actual dates.

## Calendars

- Standard: Mon-Fri 08:00-12:00, 13:00-17:00; Sat-Sun off. Exceptions (off unless hours are given): 2019-11-02 to 2019-11-03 08:00-12:00, 13:00-17:00.

## Schedule

| ID | WBS | Task | Duration | Start | Finish | Predecessors | Complete | Remaining | Baseline start | Baseline finish | Baseline duration | Total slack | Constraint |
| --- | --- | --- | --- | --- | --- | --- | --- | --- | --- | --- | --- | --- | --- |
| 1 | 1 | **EPDP - Phase 2 Policy Development** | 456d | 2019-03-04 A | 2020-11-26 |  | 96% | 17.36d | 2019-03-04 | 2020-10-06 | 419d | 0d |  |
| 2 | 1.1 | **PROJECT MANAGEMENT** | 456d | 2019-03-04 A | 2020-11-26 |  | 92% | 34.57d | 2019-03-04 | 2020-10-06 | 419d | 0d |  |
| 3 | 1.1.1 | Project start confirmed | 1d | 2019-03-04 A | 2019-03-04 A |  | 100% |  | 2019-03-04 | 2019-03-04 | 1d |  |  |
| 4 | 1.1.2 | Adopt/Confirm charter | 1d | 2019-03-05 A | 2019-03-05 A | 3 | 100% |  | 2019-03-05 | 2019-03-05 | 1d |  |  |
| 5 | 1.1.3 | Confirmation of EPDP Team | 20d | 2019-03-05 A | 2019-04-01 A | 3 | 100% |  | 2019-03-05 | 2019-04-01 | 20d |  |  |
| 6 | 1.1.4 | Appointment of EPDP Team Chair | 30d | 2019-03-05 A | 2019-04-15 A | 3 | 100% |  | 2019-03-05 | 2019-04-15 | 30d |  |  |
| 7 | 1.1.5 | Appointment of EPDP Liaison to GNSO Council | 5d | 2019-04-16 A | 2019-04-22 A | 6 | 100% |  | 2019-04-16 | 2019-04-22 | 5d |  |  |
| 8 | 1.1.6 | Chair / Staff preparations | 12d | 2019-04-16 A | 2019-05-01 A | 6 | 100% |  | 2019-04-16 | 2019-05-01 | 12d |  |  |
| 9 | 1.1.7 | **Project Management** | 454d | 2019-03-06 A | 2020-11-26 |  | 92% | 36.67d | 2019-03-06 | 2020-10-06 | 417d | 0d |  |
| 10 | 1.1.7.1 | Develop and confirm Project Plan | 90d | 2019-04-16 A | 2019-08-19 A | 6 | 100% |  | 2019-04-16 | 2019-08-19 | 90d |  |  |
| 11 | 1.1.7.2 | Adopt iterative work plan(s) | 90d | 2019-04-16 A | 2019-08-19 A | 6 | 100% |  | 2019-04-16 | 2019-08-19 | 90d |  |  |
| 12 | 1.1.7.3 | Develop Project status work products and communications | 90d | 2019-04-16 A | 2019-08-19 A | 6 | 100% |  | 2019-04-16 | 2019-08-19 | 90d |  |  |
| 13 | 1.1.7.4 | Obtain project plan approval from GNSO Council | 1d | 2019-08-22 A | 2019-08-22 A | 12 | 100% |  | 2019-08-22 | 2019-08-22 | 1d |  | start no earlier than 2019-08-22 |
| 14 | 1.1.7.5 | **Leadership Sub team** | 310d | 2019-04-16 A | 2020-06-18 |  | 93% | 21.7d | 2019-04-16 | 2020-04-30 | 275d | 95d |  |
| 15 | 1.1.7.5.1 | On-going preparation and planning of EPDP-P2 activities | 310d | 2019-04-16 A | 2020-06-18 | 6 | 93% | 21.7d | 2019-04-16 | 2020-04-30 | 275d | 95d |  |
| 16 | 1.1.7.6 | **Project Cost Support Team Sub team** | 360d | 2019-03-06 A | 2020-07-17 |  | 90% | 34.56d | 2019-03-06 | 2020-07-17 | 360d | 74d |  |
| 17 | 1.1.7.6.1 | Develop EPDP Fact Sheet | 30d | 2019-04-16 A | 2019-05-27 A | 6 | 100% |  | 2019-04-16 | 2019-05-27 | 30d |  |  |
| 18 | 1.1.7.6.2 | Request and acquire preliminary dedicated funds for additional project resources | 20d | 2019-03-06 A | 2019-04-02 A | 4 | 100% |  | 2019-03-06 | 2019-04-02 | 20d |  |  |
| 19 | 1.1.7.6.3 | Request and acquire funds for dedicated F2F sessions & facilitation services | 20d | 2019-05-02 A | 2019-05-29 A | 8 | 100% |  | 2019-05-02 | 2019-05-29 | 20d |  |  |
| 20 | 1.1.7.6.4 | Request and acquire final dedicated funds for additional project resources | 20d | 2019-08-27 A | 2019-10-08 A | 13 | 100% |  | 2019-08-27 | 2019-10-08 | 20d |  |  |
| 21 | 1.1.7.6.5 | On-going financial and resource approvals of EPDP-P2 activities | 360d | 2019-03-06 A | 2020-07-17 | 4 | 88% | 43.2d | 2019-03-06 | 2020-07-17 | 360d | 74d |  |
| 22 | 1.1.7.7 | Close project plan, Factsheet, and transition project to IPT | 20d | 2020-10-30 | 2020-11-26 | 21, 15, 335 |  |  | 2020-09-09 | 2020-10-06 | 20d | 0d |  |
| 23 | 1.2 | **EPDP DELIBERATIONS** | 332d | 2019-03-04 A | 2020-06-05 |  | 99% | 2.25d | 2019-04-03 | 2020-06-05 | 310d | 124d |  |
| 24 | 1.2.1 | First meeting of EPDP Team | 1d | 2019-05-02 A | 2019-05-02 A | 8 | 100% |  | 2019-05-02 | 2019-05-02 | 1d |  |  |
| 25 | 1.2.2 | Understand Charter, organize materials and develop initial approach | 15d | 2019-05-02 A | 2019-05-22 A | 8 | 100% |  | 2019-05-02 | 2019-05-22 | 15d |  |  |
| 26 | 1.2.3 | Develop Worksheets for Phase 2 due diligence and organize work by Priority 1 & 2 Topics | 21d | 2019-05-02 A | 2019-05-30 A | 8 | 100% |  | 2019-05-02 | 2019-05-30 | 21d |  |  |
| 27 | 1.2.4 | Review prior legal advice memos and formulate potential topics that may require advice | 21d | 2019-05-02 A | 2019-05-30 A | 8 | 100% |  | 2019-05-02 | 2019-05-30 | 21d |  |  |
| 28 | 1.2.5 | Develop definitions and terminology | 21d | 2019-05-02 A | 2019-05-30 A | 8 | 100% |  | 2019-05-02 | 2019-05-30 | 21d |  |  |

| ID | WBS | Task | Type | Duration | Start | Finish | Predecessors | Complete | Baseline start | Baseline finish | Baseline duration |
| --- | --- | --- | --- | --- | --- | --- | --- | --- | --- | --- | --- |
| 29 | 1.2.6 | **Input from other SO/ACs & GNSO SG/Cs** |  | 134d | 2019-05-23 A | 2019-11-22 A |  | 100% | 2019-05-23 | 2019-11-22 | 134d |
| 30 | 1.2.6.1 | Develop template for input |  | 5d | 2019-05-23 A | 2019-05-29 A | 25 | 100% | 2019-05-23 | 2019-05-29 | 5d |
| 31 | 1.2.6.2 | Announce input opportunity |  | 1d | 2019-05-30 A | 2019-05-30 A | 30 | 100% | 2019-05-30 | 2019-05-30 | 1d |
| 32 | 1.2.6.3 | Collect and collate input in to Review Tool |  | 28d | 2019-05-31 A | 2019-07-09 A | 31 | 100% | 2019-05-31 | 2019-07-09 | 28d |
| 33 | 1.2.6.4 | Group to review input and determine relevance to policy deliberations on issues within scope |  | 100d | 2019-07-10 A | 2019-11-22 A | 32 | 100% | 2019-07-10 | 2019-11-22 | 100d |
| 34 | 1.2.7 | **Priority 1 Deliberations** |  | 172d | 2019-05-31 A | 2020-01-23 A |  | 100% | 2019-05-31 | 2019-11-19 | 125d |
| 35 | 1.2.7.1 | **Requirements, incl. defining user groups, use cases and other criteria to determine similarities and differences** |  | 70d | 2019-05-31 A | 2019-09-05 A |  | 100% | 2019-05-31 | 2019-09-05 | 70d |
| 36 | 1.2.7.1.1 | Deliberate Groups to Use Case approach |  | 10d | 2019-06-14 A | 2019-06-27 A | 26 | 100% | 2019-06-14 | 2019-06-27 | 10d |
| 37 | 1.2.7.1.2 | Deliberate Single Use Case to establish Template |  | 10d | 2019-06-14 A | 2019-06-27 A | 26 | 100% | 2019-06-14 | 2019-06-27 | 10d |
| 38 | 1.2.7.1.3 | **Generate potential Use Cases (refer to 20+ on wiki)** |  | 70d | 2019-05-31 A | 2019-09-05 A | 37 | 100% | 2019-05-31 | 2019-09-05 | 70d |
| 39 | 1.2.7.1.3.1 | Confirm Use Case order and groups to consolidate |  | 50d | 2019-06-28 A | 2019-09-05 A |  | 100% | 2019-06-28 | 2019-09-05 | 50d |
| 40 | 1.2.7.1.3.2 | Understand Purposes and Legitimate Interest for third party disclosure |  | 10d | 2019-05-31 A | 2019-07-02 A |  | 100% | 2019-05-31 | 2019-07-02 | 10d |
| 41 | 1.2.7.1.3.3 | First reading + response |  | 50d | 2019-06-28 A | 2019-09-05 A |  | 100% | 2019-06-28 | 2019-09-05 | 50d |
| 42 | 1.2.7.1.3.4 | Deliberate other policy topics as necessary to better inform dedicated time to that topic |  | 30d | 2019-06-28 A | 2019-08-08 A |  | 100% | 2019-06-28 | 2019-08-08 | 30d |
| 43 | 1.2.7.1.3.5 | Develop subsequent draft + response |  | 50d | 2019-06-28 A | 2019-09-05 A |  | 100% | 2019-06-28 | 2019-09-05 | 50d |
| 44 | 1.2.7.1.3.6 | Second reading + adoption or discard |  | 50d | 2019-06-28 A | 2019-09-05 A |  | 100% | 2019-06-28 | 2019-09-05 | 50d |
| 45 | 1.2.7.2 | **SSAD Model & Building Blocks & Preliminary Recommendations** |  | 122d | 2019-08-09 A | 2020-01-23 A |  | 100% | 2019-08-09 | 2019-11-19 | 75d |
| 46 | 1.2.7.2.1 | **Safeguards** |  | 122d | 2019-08-09 A | 2020-01-23 A |  | 100% | 2019-08-09 | 2019-11-19 | 74.5d |
| 47 | 1.2.7.2.1.1 | Review inputs from Requirements and Use Cases |  | 5d | 2019-08-09 A | 2019-09-12 A | 38 | 100% | 2019-08-09 | 2019-09-12 | 5d |
| 48 | 1.2.7.2.1.2 | **Understand sub-topics and determine need to deliberate** |  | 90d | 2019-09-12 A | 2020-01-14 A |  | 100% | 2019-09-12 | 2019-09-26 | 10d |
| 49 | 1.2.7.2.1.2.1 | Query volume limitations | manual | 60d | 2019-09-12 A | 2019-12-03 A | 47 | 100% | 2019-09-12 | 2019-09-26 | 10d |
| 50 | 1.2.7.2.1.2.2 | Code of conduct | manual | 90d | 2019-09-12 A | 2020-01-14 A | 47 | 100% | 2019-09-12 | 2019-09-26 | 10d |
| 51 | 1.2.7.2.1.2.3 | Terms of use / disclosure agreements | manual | 90d | 2019-09-12 A | 2020-01-14 A | 47 | 100% | 2019-09-12 | 2019-09-26 | 10d |
| 52 | 1.2.7.2.1.2.4 | Privacy policies | manual | 90d | 2019-09-12 A | 2020-01-14 A | 47 | 100% | 2019-09-12 | 2019-09-26 | 10d |
| 53 | 1.2.7.2.1.2.5 | Retention and destruction of data | manual | 90d | 2019-09-12 A | 2020-01-14 A | 47 | 100% | 2019-09-12 | 2019-09-26 | 10d |
| 54 | 1.2.7.2.1.2.6 | Service level agreements | manual | 90d | 2019-09-12 A | 2020-01-14 A | 47 | 100% | 2019-09-12 | 2019-09-26 | 10d |
| 55 | 1.2.7.2.1.2.7 | Transfer of the Data | manual | 90d | 2019-09-12 A | 2020-01-14 A | 47 | 100% | 2019-09-12 | 2019-09-26 | 10d |
| 56 | 1.2.7.2.1.2.8 | Disclosure of the Data | manual | 60d | 2019-09-12 A | 2019-12-03 A | 47 | 100% | 2019-09-12 | 2019-09-26 | 10d |
| 57 | 1.2.7.2.1.2.9 | Monitoring | manual | 60d | 2019-09-12 A | 2019-12-03 A | 47 | 100% | 2019-09-12 | 2019-09-26 | 10d |
| 58 | 1.2.7.2.1.2.10 | Audit trail | manual | 60d | 2019-09-12 A | 2019-12-03 A | 47 | 100% | 2019-09-12 | 2019-09-26 | 10d |
| 59 | 1.2.7.2.1.2.11 | Retention | manual | 60d | 2019-09-12 A | 2019-12-03 A | 47 | 100% | 2019-09-12 | 2019-09-26 | 10d |
| 60 | 1.2.7.2.1.2.12 | Destruction of data | manual | 60d | 2019-09-12 A | 2019-12-03 A | 47 | 100% | 2019-09-12 | 2019-09-26 | 10d |
| 61 | 1.2.7.2.1.3 | Deliberate policy considerations and determine approach |  | 5d | 2019-09-26 A | 2019-10-03 A | 48 | 100% | 2019-09-26 | 2019-10-03 | 5d |
| 62 | 1.2.7.2.1.4 | Deliberate policy issues |  | 80d | 2019-10-03 A | 2020-01-21 A | 61 | 100% | 2019-10-03 | 2019-10-31 | 20d |
| 63 | 1.2.7.2.1.5 | Develop draft work product |  | 80d | 2019-10-03 A | 2020-01-21 A | 61 | 100% | 2019-10-03 | 2019-11-12 | 30d |
| 64 | 1.2.7.2.1.6 | Conduct First Reading + verbal and email response |  | 80d | 2019-10-03 A | 2020-01-21 A | 61 | 100% | 2019-10-03 | 2019-10-17 | 10d |
| 65 | 1.2.7.2.1.7 | Conduct Second Reading + verbal response + adoption or discard |  | 5d | 2019-11-12 A | 2020-01-23 A | 63, 64 | 100% | 2019-11-12 | 2019-11-19 | 5d |

| ID | WBS | Task | Duration | Start | Finish | Predecessors | Complete | Baseline start | Baseline finish | Baseline duration |
| --- | --- | --- | --- | --- | --- | --- | --- | --- | --- | --- |
| 66 | 1.2.7.2.2 | **Accreditation and Authentication (Credentialing)** | 55d | 2019-09-06 A | 2019-11-19 A |  | 100% | 2019-09-06 | 2019-11-19 | 55d |
| 67 | 1.2.7.2.2.1 | Understand topic and determine need to deliberate | 5d | 2019-09-06 A | 2019-09-12 A | 38 | 100% | 2019-09-06 | 2019-09-12 | 5d |
| 68 | 1.2.7.2.2.2 | Deliberate policy considerations and determine approach | 5d | 2019-09-06 A | 2019-09-12 A | 38 | 100% | 2019-09-06 | 2019-09-12 | 5d |
| 69 | 1.2.7.2.2.3 | Deliberate policy issues | 35d | 2019-09-13 A | 2019-10-31 A | 68 | 100% | 2019-09-13 | 2019-10-31 | 35d |
| 70 | 1.2.7.2.2.4 | Develop draft work product | 45d | 2019-09-13 A | 2019-11-12 A | 68 | 100% | 2019-09-13 | 2019-11-12 | 45d |
| 71 | 1.2.7.2.2.5 | Conduct First Reading + verbal and email response | 10d | 2019-09-13 A | 2019-09-26 A | 68 | 100% | 2019-09-13 | 2019-09-26 | 10d |
| 72 | 1.2.7.2.2.6 | Conduct Second Reading + verbal response + adoption or discard | 5d | 2019-11-13 A | 2019-11-19 A | 70, 71 | 100% | 2019-11-13 | 2019-11-19 | 5d |
| 73 | 1.2.7.2.3 | **Lawful Basis & Balancing Test** | 97.5d | 2019-09-06 A | 2020-01-17 A |  | 100% | 2019-09-06 | 2019-11-19 | 55d |
| 74 | 1.2.7.2.3.1 | Understand topic and determine need to deliberate | 5d | 2019-09-06 A | 2019-09-12 A | 38 | 100% | 2019-09-06 | 2019-09-12 | 5d |
| 75 | 1.2.7.2.3.2 | Deliberate policy considerations and determine approach | 5d | 2019-09-06 A | 2019-09-12 A | 38 | 100% | 2019-09-06 | 2019-09-12 | 5d |
| 76 | 1.2.7.2.3.3 | Deliberate policy issues | 90d | 2019-09-13 A | 2020-01-14 A | 75 | 100% | 2019-09-13 | 2019-10-31 | 35d |
| 77 | 1.2.7.2.3.4 | Develop draft work product | 90d | 2019-09-13 A | 2020-01-14 A | 75 | 100% | 2019-09-13 | 2019-11-12 | 45d |
| 78 | 1.2.7.2.3.5 | Conduct First Reading + verbal and email response | 90d | 2019-09-13 A | 2020-01-14 A | 75 | 100% | 2019-09-13 | 2019-09-26 | 10d |
| 79 | 1.2.7.2.3.6 | Conduct Second Reading + verbal response + adoption or discard | 5d | 2019-11-13 A | 2020-01-17 A | 77, 78 | 100% | 2019-11-13 | 2019-11-19 | 5d |
| 80 | 1.2.7.2.4 | **Determine Process publication, format and content request requirements** | 55d | 2019-09-06 A | 2019-11-19 A |  | 100% | 2019-09-06 | 2019-11-19 | 55d |
| 81 | 1.2.7.2.4.1 | Understand topic and determine need to deliberate | 5d | 2019-09-06 A | 2019-09-12 A | 38 | 100% | 2019-09-06 | 2019-09-12 | 5d |
| 82 | 1.2.7.2.4.2 | Deliberate policy considerations and determine approach | 5d | 2019-09-06 A | 2019-09-12 A | 38 | 100% | 2019-09-06 | 2019-09-12 | 5d |
| 83 | 1.2.7.2.4.3 | Deliberate policy issues | 35d | 2019-09-13 A | 2019-10-31 A | 82 | 100% | 2019-09-13 | 2019-10-31 | 35d |
| 84 | 1.2.7.2.4.4 | Develop draft work product | 45d | 2019-09-13 A | 2019-11-12 A | 82 | 100% | 2019-09-13 | 2019-11-12 | 45d |
| 85 | 1.2.7.2.4.5 | Conduct First Reading + verbal and email response | 10d | 2019-09-13 A | 2019-09-26 A | 82 | 100% | 2019-09-13 | 2019-09-26 | 10d |
| 86 | 1.2.7.2.4.6 | Conduct Second Reading + verbal response + adoption or discard | 5d | 2019-11-13 A | 2019-11-19 A | 84, 85 | 100% | 2019-11-13 | 2019-11-19 | 5d |
| 87 | 1.2.7.2.5 | **Timeline of process** | 55d | 2019-09-06 A | 2019-11-19 A |  | 100% | 2019-09-06 | 2019-11-19 | 55d |
| 88 | 1.2.7.2.5.1 | Understand topic and determine need to deliberate | 5d | 2019-09-06 A | 2019-09-12 A | 38 | 100% | 2019-09-06 | 2019-09-12 | 5d |
| 89 | 1.2.7.2.5.2 | Deliberate policy considerations and determine approach | 5d | 2019-09-06 A | 2019-09-12 A | 38 | 100% | 2019-09-06 | 2019-09-12 | 5d |
| 90 | 1.2.7.2.5.3 | Deliberate policy issues | 35d | 2019-09-13 A | 2019-10-31 A | 89 | 100% | 2019-09-13 | 2019-10-31 | 35d |
| 91 | 1.2.7.2.5.4 | Develop draft work product | 45d | 2019-09-13 A | 2019-11-12 A | 89 | 100% | 2019-09-13 | 2019-11-12 | 45d |
| 92 | 1.2.7.2.5.5 | Conduct First Reading + verbal and email response | 10d | 2019-09-13 A | 2019-09-26 A | 89 | 100% | 2019-09-13 | 2019-09-26 | 10d |
| 93 | 1.2.7.2.5.6 | Conduct Second Reading + verbal response + adoption or discard | 5d | 2019-11-13 A | 2019-11-19 A | 91, 92 | 100% | 2019-11-13 | 2019-11-19 | 5d |

| ID | WBS | Task | Duration | Start | Finish | Predecessors | Complete | Baseline start | Baseline finish | Baseline duration |
| --- | --- | --- | --- | --- | --- | --- | --- | --- | --- | --- |
| 94 | 1.2.7.2.6 | **Automation Analysis + Centralized vs. De-Centralized Models** | 97.5d | 2019-09-06 A | 2020-01-17 A |  | 100% | 2019-09-06 | 2019-11-19 | 55d |
| 95 | 1.2.7.2.6.1 | Understand topic and determine need to deliberate | 5d | 2019-09-06 A | 2019-09-12 A | 38 | 100% | 2019-09-06 | 2019-09-12 | 5d |
| 96 | 1.2.7.2.6.2 | Deliberate policy considerations and determine approach | 5d | 2019-09-06 A | 2019-09-12 A | 38 | 100% | 2019-09-06 | 2019-09-12 | 5d |
| 97 | 1.2.7.2.6.3 | Deliberate policy issues | 90d | 2019-09-13 A | 2020-01-14 A | 96 | 100% | 2019-09-13 | 2019-10-31 | 35d |
| 98 | 1.2.7.2.6.4 | Determine if automation is consistent with legal requirements/legal basis | 90d | 2019-09-13 A | 2020-01-14 A | 96 | 100% | 2019-09-13 | 2019-11-12 | 45d |
| 99 | 1.2.7.2.6.5 | Develop draft work product | 90d | 2019-09-13 A | 2020-01-14 A | 96 | 100% | 2019-09-13 | 2019-11-12 | 45d |
| 100 | 1.2.7.2.6.6 | Conduct First Reading + verbal and email response | 90d | 2019-09-13 A | 2020-01-14 A | 96 | 100% | 2019-09-13 | 2019-09-26 | 10d |
| 101 | 1.2.7.2.6.7 | Conduct Second Reading + verbal response + adoption or discard | 5d | 2019-11-13 A | 2020-01-17 A | 99, 100 | 100% | 2019-11-13 | 2019-11-19 | 5d |
| 102 | 1.2.7.2.7 | **Review possible comprehensive model and options** | 55d | 2019-09-06 A | 2019-11-19 A |  | 100% | 2019-09-06 | 2019-11-19 | 55d |
| 103 | 1.2.7.2.7.1 | Understand topic and determine need to deliberate | 5d | 2019-09-06 A | 2019-09-12 A | 38 | 100% | 2019-09-06 | 2019-09-12 | 5d |
| 104 | 1.2.7.2.7.2 | Deliberate policy considerations and determine approach | 5d | 2019-09-06 A | 2019-09-12 A | 38 | 100% | 2019-09-06 | 2019-09-12 | 5d |
| 105 | 1.2.7.2.7.3 | Deliberate policy issues | 35d | 2019-09-13 A | 2019-10-31 A | 104 | 100% | 2019-09-13 | 2019-10-31 | 35d |
| 106 | 1.2.7.2.7.4 | Develop draft work product | 45d | 2019-09-13 A | 2019-11-12 A | 104 | 100% | 2019-09-13 | 2019-11-12 | 45d |
| 107 | 1.2.7.2.7.5 | Conduct First Reading + verbal and email response | 10d | 2019-09-13 A | 2019-09-26 A | 104 | 100% | 2019-09-13 | 2019-09-26 | 10d |
| 108 | 1.2.7.2.7.6 | Conduct Second Reading + verbal response + adoption or discard | 5d | 2019-11-13 A | 2019-11-19 A | 106, 107 | 100% | 2019-11-13 | 2019-11-19 | 5d |
| 109 | 1.2.7.2.8 | **Financial sustainability** | 98.75d | 2019-09-06 A | 2020-01-20 A |  | 100% | 2019-09-06 | 2019-11-19 | 55d |
| 110 | 1.2.7.2.8.1 | Understand topic and determine need to deliberate | 5d | 2019-09-06 A | 2019-09-12 A | 38 | 100% | 2019-09-06 | 2019-09-12 | 5d |
| 111 | 1.2.7.2.8.2 | Deliberate policy considerations and determine approach | 5d | 2019-09-06 A | 2019-09-12 A | 38 | 100% | 2019-09-06 | 2019-09-12 | 5d |
| 112 | 1.2.7.2.8.3 | Deliberate policy issues | 90d | 2019-09-13 A | 2020-01-14 A | 111 | 100% | 2019-09-13 | 2019-10-31 | 35d |
| 113 | 1.2.7.2.8.4 | Develop draft work product | 90d | 2019-09-13 A | 2020-01-14 A | 111 | 100% | 2019-09-13 | 2019-11-12 | 45d |
| 114 | 1.2.7.2.8.5 | Conduct First Reading + verbal and email response | 10d | 2019-09-13 A | 2019-09-26 A | 111 | 100% | 2019-09-13 | 2019-09-26 | 10d |
| 115 | 1.2.7.2.8.6 | Conduct Second Reading + verbal response + adoption or discard | 5d | 2019-11-13 A | 2020-01-20 A | 113, 114 | 100% | 2019-11-13 | 2019-11-19 | 5d |
| 116 | 1.2.7.2.9 | **Purpose 2 Rework per Phase 1 and Board Instruction to GNSO Council** | 100d | 2019-09-06 A | 2020-01-21 A | 35 | 100% | 2019-09-06 | 2019-11-19 | 55d |
| 117 | 1.2.7.2.9.1 | Understand topic and determine need to deliberate | 5d | 2019-09-06 A | 2019-09-12 A | 38 | 100% | 2019-09-06 | 2019-09-12 | 5d |
| 118 | 1.2.7.2.9.2 | Deliberate policy considerations and determine approach | 5d | 2019-09-06 A | 2019-09-12 A | 38 | 100% | 2019-09-06 | 2019-09-12 | 5d |
| 119 | 1.2.7.2.9.3 | Deliberate policy issues | 90d | 2019-09-13 A | 2020-01-14 A | 118 | 100% | 2019-09-13 | 2019-10-31 | 35d |
| 120 | 1.2.7.2.9.4 | Develop draft work product | 90d | 2019-09-13 A | 2020-01-14 A | 118 | 100% | 2019-09-13 | 2019-11-12 | 45d |
| 121 | 1.2.7.2.9.5 | Conduct First Reading + verbal and email response | 10d | 2019-09-13 A | 2019-09-26 A | 118 | 100% | 2019-09-13 | 2019-09-26 | 10d |
| 122 | 1.2.7.2.9.6 | Conduct Second Reading + verbal response + adoption or discard | 5d | 2020-01-15 A | 2020-01-21 A | 120, 121 | 100% | 2019-11-13 | 2019-11-19 | 5d |

| ID | WBS | Task | Type | Duration | Start | Finish | Predecessors | Complete | Remaining | Baseline start | Baseline finish | Baseline duration | Total slack | Free slack |
| --- | --- | --- | --- | --- | --- | --- | --- | --- | --- | --- | --- | --- | --- | --- |
| 123 | 1.2.7.2.10 | **Authorization Provider** |  | 87.5d | 2019-09-06 A | 2020-01-03 A |  | 100% |  | 2019-09-06 | 2019-11-19 | 55d |  |  |
| 124 | 1.2.7.2.10.1 | Understand topic and determine need to deliberate |  | 5d | 2019-09-06 A | 2019-09-12 A | 38 | 100% |  | 2019-09-06 | 2019-09-12 | 5d |  |  |
| 125 | 1.2.7.2.10.2 | Deliberate policy considerations and determine approach |  | 5d | 2019-09-06 A | 2019-09-12 A | 38 | 100% |  | 2019-09-06 | 2019-09-12 | 5d |  |  |
| 126 | 1.2.7.2.10.3 | Deliberate policy issues |  | 80d | 2019-09-13 A | 2019-12-31 A | 125 | 100% |  | 2019-09-13 | 2019-10-31 | 35d |  |  |
| 127 | 1.2.7.2.10.4 | Develop draft work product |  | 80d | 2019-09-13 A | 2019-12-31 A | 125 | 100% |  | 2019-09-13 | 2019-11-12 | 45d |  |  |
| 128 | 1.2.7.2.10.5 | Conduct First Reading + verbal and email response |  | 10d | 2019-09-13 A | 2019-09-26 A | 125 | 100% |  | 2019-09-13 | 2019-09-26 | 10d |  |  |
| 129 | 1.2.7.2.10.6 | Conduct Second Reading + verbal response + adoption or discard |  | 5d | 2019-11-13 A | 2020-01-03 A | 127, 128 | 100% |  | 2019-11-13 | 2019-11-19 | 5d |  |  |
| 130 | 1.2.7.3 | Priority 1 draft zero documents for LA1 F2F2 | milestone | 0d | 2019-09-05 A | 2019-09-05 A | 35 | 100% |  | 2019-09-05 | 2019-09-05 | 0d |  |  |
| 131 | 1.2.7.4 | Priority 1 draft 1.0 documents for ICANN66 Montreal | milestone | 0d | 2019-10-31 A | 2019-10-31 A | 62, 69, 76, 83, 90, 97, 105, 112, 119, 126 | 100% |  | 2019-10-31 | 2019-10-31 | 0d |  |  |
| 132 | 1.2.8 | **Priority 2 Deliberations (Issues carried from Phase 1)** |  | 252d | 2019-05-31 A | 2020-05-14 |  | 99% | 3.02d | 2019-05-31 | 2020-04-23 | 237d | 140d |  |
| 133 | 1.2.8.1 | Organize Priority 2 topics |  | 1d | 2019-05-31 A | 2019-05-31 A | 26 | 100% |  | 2019-05-31 | 2019-05-31 | 1d |  |  |
| 134 | 1.2.8.2 | **Display of information of affiliated vs. accredited privacy / proxy providers** |  | 245d | 2019-06-03 A | 2020-05-06 |  | 99% | 2.63d | 2019-06-03 | 2020-04-15 | 230d | 146d |  |
| 135 | 1.2.8.2.1 | Initial Scoping of topic |  | 5d | 2019-06-03 A | 2019-06-07 A | 133 | 100% |  | 2019-06-03 | 2019-06-07 | 5d |  |  |
| 136 | 1.2.8.2.2 | **Understand topic and determine need to deliberate** |  | 110d | 2019-06-10 A | 2019-11-06 A |  | 100% |  | 2019-06-10 | 2019-11-06 | 110d |  |  |
| 137 | 1.2.8.2.2.1 | PPSAI IRT briefing to determine how their work compliments or depends on EPDP |  | 110d | 2019-06-10 A | 2019-11-06 A | 135 | 100% |  | 2019-06-10 | 2019-11-06 | 110d |  |  |
| 138 | 1.2.8.2.2.2 | Determine if briefing regarding a data privacy impact assessment on the PPSAI program is required |  | 110d | 2019-06-10 A | 2019-11-06 A | 135 | 100% |  | 2019-06-10 | 2019-11-06 | 110d |  |  |
| 139 | 1.2.8.2.2.3 | Determine if answers to legal questions are required |  | 110d | 2019-06-10 A | 2019-11-06 A | 135 | 100% |  | 2019-06-10 | 2019-11-06 | 110d |  |  |
| 140 | 1.2.8.2.3 | Deliberate policy considerations and determine approach |  | 5d | 2019-11-07 A | 2019-11-13 A | 136 | 100% |  | 2019-11-07 | 2019-11-13 | 5d |  |  |
| 141 | 1.2.8.2.4 | Deliberate policy issues |  | 105d | 2019-11-14 A | 2020-04-08 A | 140 | 100% |  | 2019-11-14 | 2020-03-18 | 90d |  |  |
| 142 | 1.2.8.2.5 | Develop draft work product |  | 10d | 2020-04-09 A | 2020-04-22 A | 141 | 100% |  | 2020-03-19 | 2020-04-01 | 10d |  |  |
| 143 | 1.2.8.2.6 | Conduct First Reading + verbal and email response |  | 5d | 2020-04-23 A | 2020-04-29 | 142 | 50% | 2.5d | 2020-04-02 | 2020-04-08 | 5d | 2.5d | 0d |
| 144 | 1.2.8.2.7 | Conduct Second Reading + verbal response + adoption or discard |  | 5d | 2020-04-30 A | 2020-05-06 | 143 | 50% | 2.5d | 2020-04-09 | 2020-04-15 | 5d | 146d |  |
| 145 | 1.2.8.3 | **Legal vs. Natural** |  | 245d | 2019-06-03 A | 2020-05-06 |  | 99% | 2.13d | 2019-06-03 | 2020-04-15 | 230d | 146d |  |
| 146 | 1.2.8.3.1 | Initial Scoping of topic |  | 5d | 2019-06-03 A | 2019-06-07 A | 133 | 100% |  | 2019-06-03 | 2019-06-07 | 5d |  |  |

| ID | WBS | Task | Duration | Start | Finish | Predecessors | Complete | Remaining | Baseline start | Baseline finish | Baseline duration | Total slack | Free slack | Constraint |
| --- | --- | --- | --- | --- | --- | --- | --- | --- | --- | --- | --- | --- | --- | --- |
| 147 | 1.2.8.3.2 | **Understand topic and determine need to deliberate** | 110d | 2019-06-10 A | 2019-11-06 A |  | 100% |  | 2019-06-10 | 2019-11-06 | 110d |  |  |  |
| 148 | 1.2.8.3.2.1 | Receive briefing from Bird & Bird on legal vs. natural memo | 110d | 2019-06-10 A | 2019-11-06 A | 146 | 100% |  | 2019-06-10 | 2019-11-06 | 110d |  |  |  |
| 149 | 1.2.8.3.2.2 | Determine if answers to legal questions are required | 110d | 2019-06-10 A | 2019-11-06 A | 146 | 100% |  | 2019-06-10 | 2019-11-06 | 110d |  |  |  |
| 150 | 1.2.8.3.2.3 | EPDP Team to confirm with ICANN Org expected next steps and timing to conduct and publish the study results. | 110d | 2019-06-10 A | 2019-11-06 A | 146 | 100% |  | 2019-06-10 | 2019-11-06 | 110d |  |  |  |
| 151 | 1.2.8.3.2.4 | EPDP Team or Sub-team to work with ICANN org on this study, including providing questions and/or relevant background to assist in informing the study by 1 July 2019. | 110d | 2019-06-10 A | 2019-11-06 A | 146 | 100% |  | 2019-06-10 | 2019-11-06 | 110d |  |  |  |
| 152 | 1.2.8.3.3 | Deliberate policy considerations and determine approach | 5d | 2019-11-07 A | 2019-11-13 A | 147 | 100% |  | 2019-11-07 | 2019-11-13 | 5d |  |  |  |
| 153 | 1.2.8.3.4 | Deliberate policy issues | 105d | 2019-11-14 A | 2020-04-08 A | 152 | 100% |  | 2019-11-14 | 2020-03-18 | 90d |  |  |  |
| 154 | 1.2.8.3.5 | Develop draft work product | 10d | 2020-04-09 A | 2020-04-22 A | 153 | 100% |  | 2020-03-19 | 2020-04-01 | 10d |  |  |  |
| 155 | 1.2.8.3.6 | Conduct First Reading + verbal and email response | 5d | 2020-04-23 A | 2020-04-29 | 154 | 50% | 2.5d | 2020-04-02 | 2020-04-08 | 5d | 2.5d | 0d |  |
| 156 | 1.2.8.3.7 | Conduct Second Reading + verbal response + adoption or discard | 5d | 2020-04-30 A | 2020-05-06 | 155 | 50% | 2.5d | 2020-04-09 | 2020-04-15 | 5d | 146d |  |  |
| 157 | 1.2.8.4 | **City Field** | 245d | 2019-06-11 A | 2020-05-14 |  | 98% | 3.77d | 2019-06-11 | 2020-04-23 | 230d | 140d |  |  |
| 158 | 1.2.8.4.1 | Initial Scoping of topic | 5d | 2019-06-11 A | 2019-06-17 A | 133 | 100% |  | 2019-06-11 | 2019-06-17 | 5d |  |  | start no earlier than 2019-06-11 |
| 159 | 1.2.8.4.2 | **Understand topic and determine need to deliberate** | 110d | 2019-06-18 A | 2019-11-14 A |  | 100% |  | 2019-06-18 | 2019-11-14 | 110d |  |  |  |
| 160 | 1.2.8.4.2.1 | Receive briefing from Bird & Bird on city field memo | 110d | 2019-06-18 A | 2019-11-14 A | 158 | 100% |  | 2019-06-18 | 2019-11-14 | 110d |  |  |  |
| 161 | 1.2.8.4.2.2 | Determine if answers to legal questions are required | 80d | 2019-06-18 A | 2019-10-07 A | 158 | 100% |  | 2019-06-18 | 2019-10-07 | 80d |  |  |  |
| 162 | 1.2.8.4.3 | Deliberate policy considerations and determine approach | 5d | 2019-11-15 A | 2019-11-21 A | 159 | 100% |  | 2019-11-15 | 2019-11-21 | 5d |  |  | start no earlier than 2019-06-11 |
| 163 | 1.2.8.4.4 | Deliberate policy issues | 105d | 2019-11-22 A | 2020-04-16 A | 162 | 100% |  | 2019-11-22 | 2020-03-26 | 90d |  |  |  |
| 164 | 1.2.8.4.5 | Develop draft work product | 10d | 2020-04-17 A | 2020-04-30 A | 163 | 100% |  | 2020-03-27 | 2020-04-09 | 10d |  |  |  |
| 165 | 1.2.8.4.6 | Conduct First Reading + verbal and email response | 5d | 2020-05-01 A | 2020-05-07 | 164 | 50% | 2.5d | 2020-04-10 | 2020-04-16 | 5d | 2.5d | 0d |  |
| 166 | 1.2.8.4.7 | Conduct Second Reading + verbal response + adoption or discard | 5d | 2020-05-08 A | 2020-05-14 | 165 | 50% | 2.5d | 2020-04-17 | 2020-04-23 | 5d | 140d |  |  |
| 167 | 1.2.8.5 | **Data Retention** | 245d | 2019-06-11 A | 2020-05-14 |  | 98% | 5d | 2019-06-11 | 2020-04-23 | 230d | 140d |  |  |
| 168 | 1.2.8.5.1 | Initial Scoping of topic | 5d | 2019-06-11 A | 2019-06-17 A | 133 | 100% |  | 2019-06-11 | 2019-06-17 | 5d |  |  | start no earlier than 2019-06-11 |
| 169 | 1.2.8.5.2 | **Understand topic and determine need to deliberate** | 110d | 2019-06-18 A | 2019-11-14 A |  | 100% |  | 2019-06-18 | 2019-11-14 | 110d |  |  |  |
| 170 | 1.2.8.5.2.1 | Confirm with ICANN org when the review of all of ICANN org's processes and procedures to identify and document the instances in which personal data is requested beyond the life of domain name registration is expected to be completed. | 110d | 2019-06-18 A | 2019-11-14 A | 168 | 100% |  | 2019-06-18 | 2019-11-14 | 110d |  |  |  |
| 171 | 1.2.8.5.3 | Deliberate policy considerations and determine approach | 5d | 2019-11-15 A | 2019-11-21 A | 169 | 100% |  | 2019-11-15 | 2019-11-21 | 5d |  |  | start no earlier than 2019-06-11 |

| ID | WBS | Task | Duration | Start | Finish | Predecessors | Complete | Remaining | Baseline start | Baseline finish | Baseline duration | Total slack | Free slack | Constraint |
| --- | --- | --- | --- | --- | --- | --- | --- | --- | --- | --- | --- | --- | --- | --- |
| 172 | 1.2.8.5.4 | **Deliberate policy issues** | 105d | 2019-11-22 A | 2020-04-16 A |  | 100% |  | 2019-11-22 | 2020-03-26 | 90d |  |  |  |
| 173 | 1.2.8.5.4.1 | Confirm whether the data retention requirements recommended in phase 1 are to be confirmed or whether updates are needed | 105d | 2019-11-22 A | 2020-04-16 A | 171 | 100% |  | 2019-11-22 | 2020-03-26 | 90d |  |  |  |
| 174 | 1.2.8.5.5 | Develop draft work product | 10d | 2020-04-17 A | 2020-04-30 A | 172 | 100% |  | 2020-03-27 | 2020-04-09 | 10d |  |  |  |
| 175 | 1.2.8.5.6 | Conduct First Reading + verbal and email response | 5d | 2020-05-01 A | 2020-05-07 | 174 | 50% | 2.5d | 2020-04-10 | 2020-04-16 | 5d | 2.5d | 0d |  |
| 176 | 1.2.8.5.7 | Conduct Second Reading + verbal response + adoption or discard | 5d | 2020-05-08 A | 2020-05-14 | 175 | 50% | 2.5d | 2020-04-17 | 2020-04-23 | 5d | 140d |  |  |
| 177 | 1.2.8.6 | **Additional purpose for ICANN’s OCTO** | 235d | 2019-06-17 A | 2020-05-06 |  | 99% | 3.51d | 2019-06-17 | 2020-04-15 | 220d | 146d |  |  |
| 178 | 1.2.8.6.1 | Initial Scoping of topic | 5d | 2019-06-17 A | 2019-06-21 A | 133 | 100% |  | 2019-06-17 | 2019-06-21 | 5d |  |  | start no earlier than 2019-06-17 |
| 179 | 1.2.8.6.2 | **Understand topic and determine need to deliberate** | 100d | 2019-06-24 A | 2019-11-06 A |  | 100% |  | 2019-06-24 | 2019-11-06 | 100d |  |  |  |
| 180 | 1.2.8.6.2.1 | Further to EPDP-P1 Rec#2, EPDP Team to draft question to ICANN org, to inform next steps. | 100d | 2019-06-24 A | 2019-11-06 A | 178 | 100% |  | 2019-06-24 | 2019-11-06 | 100d |  |  |  |
| 181 | 1.2.8.6.2.2 | Determine if answers to legal questions are required | 100d | 2019-06-24 A | 2019-11-06 A | 178 | 100% |  | 2019-06-24 | 2019-11-06 | 100d |  |  |  |
| 182 | 1.2.8.6.3 | Deliberate policy considerations and determine approach | 5d | 2019-11-07 A | 2019-11-13 A | 179 | 100% |  | 2019-11-07 | 2019-11-13 | 5d |  |  | start no earlier than 2019-06-17 |
| 183 | 1.2.8.6.4 | Deliberate policy issues | 105d | 2019-11-14 A | 2020-04-08 A | 182 | 100% |  | 2019-11-14 | 2020-03-18 | 90d |  |  |  |
| 184 | 1.2.8.6.5 | Develop draft work product | 10d | 2020-04-09 A | 2020-04-22 A | 183 | 100% |  | 2020-03-19 | 2020-04-01 | 10d |  |  |  |
| 185 | 1.2.8.6.6 | Conduct First Reading + verbal and email response | 5d | 2020-04-23 A | 2020-04-29 | 184 | 50% | 2.5d | 2020-04-02 | 2020-04-08 | 5d | 2.5d | 0d |  |
| 186 | 1.2.8.6.7 | Conduct Second Reading + verbal response + adoption or discard | 5d | 2020-04-30 A | 2020-05-06 | 185 | 50% | 2.5d | 2020-04-09 | 2020-04-15 | 5d | 146d |  |  |
| 187 | 1.2.8.7 | **Feasibility of unique contacts to have uniform anonymized email address** | 240d | 2019-06-17 A | 2020-05-13 |  | 98% | 5d | 2019-06-17 | 2020-04-01 | 210d | 141d |  |  |
| 188 | 1.2.8.7.1 | Initial Scoping of topic | 5d | 2019-06-17 A | 2019-06-21 A | 133 | 100% |  | 2019-06-17 | 2019-06-21 | 5d |  |  | start no earlier than 2019-06-17 |
| 189 | 1.2.8.7.2 | **Understand topic and determine need to deliberate** | 90d | 2019-06-24 A | 2019-10-25 A |  | 100% |  | 2019-06-24 | 2019-10-25 | 90d |  |  |  |
| 190 | 1.2.8.7.2.1 | Determine if answers to legal questions are required | 90d | 2019-06-24 A | 2019-10-25 A | 188 | 100% |  | 2019-06-24 | 2019-10-25 | 90d |  |  |  |
| 191 | 1.2.8.7.3 | Deliberate policy considerations and determine approach | 5d | 2019-10-28 A | 2019-11-01 A | 189 | 100% |  | 2019-10-28 | 2019-11-01 | 5d |  |  | start no earlier than 2019-06-17 |
| 192 | 1.2.8.7.4 | Deliberate policy issues | 120d | 2019-11-02 A | 2020-04-15 A | 191 | 100% |  | 2019-11-02 | 2020-03-04 | 90d |  |  |  |
| 193 | 1.2.8.7.5 | Develop draft work product | 10d | 2020-04-16 A | 2020-04-29 A | 192 | 100% |  | 2020-03-05 | 2020-03-18 | 10d |  |  |  |
| 194 | 1.2.8.7.6 | Conduct First Reading + verbal and email response | 5d | 2020-04-30 A | 2020-05-06 | 193 | 50% | 2.5d | 2020-03-19 | 2020-03-25 | 5d | 2.5d | 0d |  |
| 195 | 1.2.8.7.7 | Conduct Second Reading + verbal response + adoption or discard | 5d | 2020-05-07 A | 2020-05-13 | 194 | 50% | 2.5d | 2020-03-26 | 2020-04-01 | 5d | 141d |  |  |

| ID | WBS | Task | Type | Duration | Start | Finish | Predecessors | Complete | Remaining | Baseline start | Baseline finish | Baseline duration | Total slack | Constraint |
| --- | --- | --- | --- | --- | --- | --- | --- | --- | --- | --- | --- | --- | --- | --- |
| 196 | 1.2.8.8 | **Data Accuracy and the WHOIS Accuracy Reporting System [Removed from Phase 2 Scope]** |  | 225d | 2019-07-09 A | 2020-05-14 A |  | 100% |  | 2019-07-09 | 2020-04-23 | 210d |  |  |
| 197 | 1.2.8.8.1 | Initial Scoping of topic |  | 5d | 2019-07-09 A | 2019-07-15 A | 133 | 100% |  | 2019-07-09 | 2019-07-15 | 5d |  | start no earlier than 2019-07-09 |
| 198 | 1.2.8.8.2 | **Understand topic and determine need to deliberate** |  | 90d | 2019-07-16 A | 2019-11-14 A |  | 100% |  | 2019-07-16 | 2019-11-14 | 90d |  |  |
| 199 | 1.2.8.8.2.1 | Receive briefing from Bird & Bird on city field memo |  | 90d | 2019-07-16 A | 2019-11-14 A | 197 | 100% |  | 2019-07-16 | 2019-11-14 | 90d |  |  |
| 200 | 1.2.8.8.2.2 | Determine if answers to legal questions are required |  | 90d | 2019-07-16 A | 2019-11-14 A | 197 | 100% |  | 2019-07-16 | 2019-11-14 | 90d |  |  |
| 201 | 1.2.8.8.3 | Deliberate policy considerations and determine approach |  | 5d | 2019-11-15 A | 2019-11-21 A | 198 | 100% |  | 2019-11-15 | 2019-11-21 | 5d |  | start no earlier than 2019-07-09 |
| 202 | 1.2.8.8.4 | Deliberate policy issues |  | 105d | 2019-11-22 A | 2020-04-16 A | 201 | 100% |  | 2019-11-22 | 2020-03-26 | 90d |  |  |
| 203 | 1.2.8.8.5 | Develop draft work product |  | 10d | 2020-04-17 A | 2020-04-30 A | 202 | 100% |  | 2020-03-27 | 2020-04-09 | 10d |  |  |
| 204 | 1.2.8.8.6 | Conduct First Reading + verbal and email response |  | 5d | 2020-05-01 A | 2020-05-07 A | 203 | 100% |  | 2020-04-10 | 2020-04-16 | 5d |  |  |
| 205 | 1.2.8.8.7 | Conduct Second Reading + verbal response + adoption or discard |  | 5d | 2020-05-08 A | 2020-05-14 A | 204 | 100% |  | 2020-04-17 | 2020-04-23 | 5d |  |  |
| 206 | 1.2.9 | **Unplanned Issues & Tasks** |  | 90d | 2019-11-02 A | 2020-03-04 A |  | 100% |  | 2019-12-04 | 2020-03-24 | 80d |  |  |
| 207 | 1.2.9.1 | **Phase 2 - Financial Costing Estimate - ICANN Org Finance** |  | 60d | 2019-11-25 A | 2020-02-14 A |  | 100% |  | 2019-12-04 | 2020-03-24 | 80d |  |  |
| 208 | 1.2.9.1.1 | Develop a cost model on proposed SSAD |  | 60d | 2019-11-25 A | 2020-02-14 A |  | 100% |  | 2019-12-04 | 2019-12-10 | 5d |  | start no earlier than 2019-11-25 |
| 209 | 1.2.9.2 | **Phase 2 - Strawberry Paper / EDPB Input** |  | 90d | 2019-11-02 A | 2020-03-04 A |  | 100% |  | 2019-12-04 | 2020-03-24 | 80d |  |  |
| 210 | 1.2.9.2.1 | Await input on TSG/UAM Model from EDPB |  | 90d | 2019-11-02 A | 2020-03-04 A |  | 100% |  | 2019-12-04 | 2019-12-10 | 5d |  | start no earlier than 2019-11-02 |
| 211 | 1.2.10 | **Legal Sub team** |  | 183d | 2019-05-30 A | 2020-02-06 A |  | 100% |  | 2019-05-30 | 2019-11-28 | 133d |  |  |
| 212 | 1.2.10.1 | Establish operating framework for handling legal advice requirements |  | 33d | 2019-05-30 A | 2019-07-15 A |  | 100% |  | 2019-05-30 | 2019-07-15 | 33d |  | start no earlier than 2019-05-30 |
| 213 | 1.2.10.2 | Select members and establish chair |  | 33d | 2019-05-30 A | 2019-07-15 A |  | 100% |  | 2019-05-30 | 2019-07-15 | 33d |  | start no earlier than 2019-05-30 |
| 214 | 1.2.10.3 | On-going review of legal questions / advice and interaction with counsel for Initial Report |  | 150d | 2019-07-16 A | 2020-02-06 A | 212 | 100% |  | 2019-07-16 | 2019-11-28 | 100d |  |  |
| 215 | 1.2.11 | **Key Events** |  | 332d | 2019-03-04 A | 2020-06-05 |  | 99% | 4.1d | 2019-04-03 | 2020-06-05 | 310d | 124d |  |
| 216 | 1.2.11.1 | **EPDP Team F2F Meeting - Marrakech (24-27 Jun 2019)** |  | 111d | 2019-04-03 A | 2019-09-04 A |  | 100% |  | 2019-04-03 | 2019-09-04 | 111d |  |  |
| 217 | 1.2.11.1.1 | Determine requirements and scope |  | 1d | 2019-04-03 A | 2019-04-03 A | 18 | 100% |  | 2019-04-03 | 2019-04-03 | 1d |  |  |
| 218 | 1.2.11.1.2 | Obtain PCST approval |  | 10d | 2019-04-04 A | 2019-04-17 A | 217 | 100% |  | 2019-04-04 | 2019-04-17 | 10d |  |  |
| 219 | 1.2.11.1.3 | Interact with Meetings Team |  | 75d | 2019-04-18 A | 2019-07-31 A | 218 | 100% |  | 2019-04-18 | 2019-07-31 | 75d |  |  |
| 220 | 1.2.11.1.4 | Engage EPDP team to confirm RSVPs and manage applications for travel support |  | 30d | 2019-04-18 A | 2019-05-29 A | 218 | 100% |  | 2019-04-18 | 2019-05-29 | 30d |  |  |
| 221 | 1.2.11.1.5 | Engage facilitators - not required | milestone | 0d | 2019-04-17 A | 2019-04-17 A | 218 | 100% |  | 2019-04-17 | 2019-04-17 | 0d |  |  |
| 222 | 1.2.11.1.6 | Plan agenda |  | 45d | 2019-04-18 A | 2019-06-19 A | 218 | 100% |  | 2019-04-18 | 2019-06-19 | 45d |  |  |
| 223 | 1.2.11.1.7 | Confirm Day 0 work products (see tasks above) | milestone | 0d | 2019-06-13 A | 2019-06-13 A | 218, 38 | 100% |  | 2019-06-13 | 2019-06-13 | 0d |  |  |
| 224 | 1.2.11.1.8 | Day 0 preparations |  | 1d | 2019-06-21 A | 2019-06-21 A | 222 | 100% |  | 2019-06-21 | 2019-06-21 | 1d |  | start no earlier than 2019-06-21 |
| 225 | 1.2.11.1.9 | Day 1 sessions |  | 1d | 2019-06-25 A | 2019-06-25 A | 224 | 100% |  | 2019-06-25 | 2019-06-25 | 1d |  | start no earlier than 2019-06-25 |
| 226 | 1.2.11.1.10 | Day 2 sessions |  | 1d | 2019-06-27 A | 2019-06-27 A | 225 | 100% |  | 2019-06-27 | 2019-06-27 | 1d |  | start no earlier than 2019-06-27 |
| 227 | 1.2.11.1.11 | F2F Recon and Sitrep | milestone | 0d | 2019-06-27 A | 2019-06-27 A | 226 | 100% |  | 2019-06-27 | 2019-06-27 | 0d |  |  |
| 228 | 1.2.11.1.12 | Communicate outcomes |  | 10d | 2019-06-28 A | 2019-07-11 A | 227 | 100% |  | 2019-06-28 | 2019-07-11 | 10d |  |  |
| 229 | 1.2.11.1.13 | Manage financial invoice, payment confirmation, and tracking (report to PCST) |  | 100d | 2019-04-18 A | 2019-09-04 A | 218 | 100% |  | 2019-04-18 | 2019-09-04 | 100d |  |  |
| 230 | 1.2.11.1.14 | Close F2F | milestone | 0d | 2019-09-04 A | 2019-09-04 A | 229 | 100% |  | 2019-09-04 | 2019-09-04 | 0d |  |  |

| ID | WBS | Task | Type | Duration | Start | Finish | Predecessors | Complete | Baseline start | Baseline finish | Baseline duration | Constraint |
| --- | --- | --- | --- | --- | --- | --- | --- | --- | --- | --- | --- | --- |
| 231 | 1.2.11.2 | **EPDP Team F2F Meeting - Los Angeles (08-11 Sept 2019)** |  | 131d | 2019-05-30 A | 2019-11-26 A |  | 100% | 2019-05-30 | 2019-11-26 | 131d |  |
| 232 | 1.2.11.2.1 | Determine requirements and scope |  | 1d | 2019-05-30 A | 2019-05-30 A | 19 | 100% | 2019-05-30 | 2019-05-30 | 1d |  |
| 233 | 1.2.11.2.2 | Obtain PCST approval |  | 20d | 2019-05-31 A | 2019-06-27 A | 232 | 100% | 2019-05-31 | 2019-06-27 | 20d |  |
| 234 | 1.2.11.2.3 | Interact with Meetings Team |  | 100d | 2019-06-07 A | 2019-10-24 A | 233 | 100% | 2019-06-07 | 2019-10-24 | 100d |  |
| 235 | 1.2.11.2.4 | Evaluate locations and reserve hotel and facilities |  | 25d | 2019-06-07 A | 2019-07-11 A | 233 | 100% | 2019-06-07 | 2019-07-11 | 25d |  |
| 236 | 1.2.11.2.5 | Engage EPDP team to confirm RSVPs and manage applications for travel support |  | 30d | 2019-07-12 A | 2019-08-22 A | 235 | 100% | 2019-07-12 | 2019-08-22 | 30d |  |
| 237 | 1.2.11.2.6 | Engage hotel and facilities support teams |  | 70d | 2019-07-12 A | 2019-10-17 A | 235 | 100% | 2019-07-12 | 2019-10-17 | 70d |  |
| 238 | 1.2.11.2.7 | Research and schedule events as necessary |  | 45d | 2019-07-12 A | 2019-09-12 A | 235 | 100% | 2019-07-12 | 2019-09-12 | 45d |  |
| 239 | 1.2.11.2.8 | Engage facilitators |  | 75d | 2019-06-07 A | 2019-09-19 A | 233 | 100% | 2019-06-07 | 2019-09-19 | 75d |  |
| 240 | 1.2.11.2.9 | Plan agenda |  | 60d | 2019-06-07 A | 2019-09-11 A | 233 | 100% | 2019-06-07 | 2019-09-11 | 60d |  |
| 241 | 1.2.11.2.10 | Confirm draft zero work products (see tasks above) | milestone | 0d | 2019-09-05 A | 2019-09-05 A | 233, 130 | 100% | 2019-09-05 | 2019-09-05 | 0d |  |
| 242 | 1.2.11.2.11 | Day 0 preparations | manual | 1d | 2019-09-08 A | 2019-09-08 A | 240 | 100% | 2019-09-08 | 2019-09-08 | 1d |  |
| 243 | 1.2.11.2.12 | Day 1 sessions |  | 1d | 2019-09-09 A | 2019-09-09 A | 242 | 100% | 2019-09-09 | 2019-09-09 | 1d |  |
| 244 | 1.2.11.2.13 | Day 2 sessions |  | 1d | 2019-09-10 A | 2019-09-10 A | 243 | 100% | 2019-09-10 | 2019-09-10 | 1d |  |
| 245 | 1.2.11.2.14 | Day 3 sessions |  | 1d | 2019-09-11 A | 2019-09-11 A | 244 | 100% | 2019-09-11 | 2019-09-11 | 1d |  |
| 246 | 1.2.11.2.15 | F2F Recon and Sitrep | milestone | 0d | 2019-09-11 A | 2019-09-11 A | 245 | 100% | 2019-09-11 | 2019-09-11 | 0d |  |
| 247 | 1.2.11.2.16 | Communicate outcomes |  | 10d | 2019-09-12 A | 2019-09-25 A | 246 | 100% | 2019-09-12 | 2019-09-25 | 10d |  |
| 248 | 1.2.11.2.17 | Manage financial invoice, payment confirmation, and tracking (report to PCST) |  | 110d | 2019-06-28 A | 2019-11-26 A | 233 | 100% | 2019-06-28 | 2019-11-26 | 110d |  |
| 249 | 1.2.11.2.18 | Close F2F | milestone | 0d | 2019-11-26 A | 2019-11-26 A | 248 | 100% | 2019-11-26 | 2019-11-26 | 0d |  |
| 250 | 1.2.11.3 | **EPDP Team F2F Meeting - Montreal (02-07 Nov 2019)** |  | 106d | 2019-08-23 A | 2020-01-15 A |  | 100% | 2019-08-23 | 2020-01-15 | 106d |  |
| 251 | 1.2.11.3.1 | Determine requirements and scope |  | 1d | 2019-08-23 A | 2019-08-23 A | 13 | 100% | 2019-08-23 | 2019-08-23 | 1d |  |
| 252 | 1.2.11.3.2 | Obtain PCST approval |  | 5d | 2019-08-26 A | 2019-08-30 A | 251 | 100% | 2019-08-26 | 2019-08-30 | 5d |  |
| 253 | 1.2.11.3.3 | Interact with Meetings Team |  | 75d | 2019-09-02 A | 2019-12-11 A | 252 | 100% | 2019-09-02 | 2019-12-11 | 75d |  |
| 254 | 1.2.11.3.4 | Engage EPDP team to confirm RSVPs and manage applications for travel support |  | 30d | 2019-09-02 A | 2019-10-11 A | 252 | 100% | 2019-09-02 | 2019-10-11 | 30d |  |
| 255 | 1.2.11.3.5 | Engage facilitators | milestone | 0d | 2019-08-30 A | 2019-08-30 A | 252 | 100% | 2019-08-30 | 2019-08-30 | 0d |  |
| 256 | 1.2.11.3.6 | Plan agenda |  | 40d | 2019-09-02 A | 2019-10-25 A | 252 | 100% | 2019-09-02 | 2019-10-25 | 40d |  |
| 257 | 1.2.11.3.7 | Confirm 1.0 draft work products (see tasks above) | milestone | 0d | 2019-10-31 A | 2019-10-31 A | 252, 131 | 100% | 2019-10-31 | 2019-10-31 | 0d |  |
| 258 | 1.2.11.3.8 | Day 0 preparations |  | 1d | 2019-11-01 A | 2019-11-01 A | 256 | 100% | 2019-11-01 | 2019-11-01 | 1d | start no earlier than 2019-11-01 |
| 259 | 1.2.11.3.9 | Day 1 sessions |  | 1d | 2019-11-02 A | 2019-11-02 A | 258 | 100% | 2019-11-02 | 2019-11-02 | 1d | start no earlier than 2019-11-02 |
| 260 | 1.2.11.3.10 | Day 2 sessions |  | 1d | 2019-11-03 A | 2019-11-03 A | 259 | 100% | 2019-11-03 | 2019-11-03 | 1d | start no earlier than 2019-11-03 |
| 261 | 1.2.11.3.11 | F2F Recon and Sitrep | milestone | 0d | 2019-11-03 A | 2019-11-03 A | 260 | 100% | 2019-11-03 | 2019-11-03 | 0d |  |
| 262 | 1.2.11.3.12 | Communicate outcomes |  | 10d | 2019-11-04 A | 2019-11-15 A | 261 | 100% | 2019-11-04 | 2019-11-15 | 10d |  |
| 263 | 1.2.11.3.13 | Manage financial invoice, payment confirmation, and tracking (report to PCST) |  | 100d | 2019-09-02 A | 2020-01-15 A | 252 | 100% | 2019-09-02 | 2020-01-15 | 100d |  |
| 264 | 1.2.11.3.14 | Close F2F | milestone | 0d | 2020-01-15 A | 2020-01-15 A | 263 | 100% | 2020-01-15 | 2020-01-15 | 0d |  |

| ID | WBS | Task | Type | Duration | Start | Finish | Predecessors | Complete | Remaining | Baseline start | Baseline finish | Baseline duration | Total slack | Free slack | Constraint |
| --- | --- | --- | --- | --- | --- | --- | --- | --- | --- | --- | --- | --- | --- | --- | --- |
| 265 | 1.2.11.4 | **EPDP Team F2F Meeting - Los Angeles (27-30 Jan 2020)** |  | 135d | 2019-09-24 A | 2020-03-26 |  | 96% | 5.66d | 2019-09-24 | 2020-03-26 | 135d | 175d |  |  |
| 266 | 1.2.11.4.1 | Determine requirements and scope |  | 1d | 2019-09-24 A | 2019-09-24 A | 20 | 100% |  | 2019-09-24 | 2019-09-24 | 1d |  |  |  |
| 267 | 1.2.11.4.2 | Obtain PCST approval |  | 5d | 2019-09-24 A | 2019-09-30 A | 20 | 100% |  | 2019-09-24 | 2019-09-30 | 5d |  |  |  |
| 268 | 1.2.11.4.3 | Interact with Meetings Team |  | 100d | 2019-10-01 A | 2020-02-13 A | 267 | 100% |  | 2019-10-01 | 2020-02-13 | 100d |  |  |  |
| 269 | 1.2.11.4.4 | Evaluate locations and reserve hotel and facilities |  | 30d | 2019-10-01 A | 2019-11-07 A | 267 | 100% |  | 2019-10-01 | 2019-11-07 | 30d |  |  |  |
| 270 | 1.2.11.4.5 | Engage EPDP team to confirm RSVPs and manage applications for travel support |  | 30d | 2019-11-08 A | 2019-12-19 A | 269 | 100% |  | 2019-11-08 | 2019-12-19 | 30d |  |  |  |
| 271 | 1.2.11.4.6 | Engage hotel and facilities support teams |  | 90d | 2019-11-08 A | 2020-03-12 A | 269 | 100% |  | 2019-11-08 | 2020-03-12 | 90d |  |  |  |
| 272 | 1.2.11.4.7 | Research and schedule events as necessary |  | 50d | 2019-11-08 A | 2020-01-16 A | 269 | 100% |  | 2019-11-08 | 2020-01-16 | 50d |  |  |  |
| 273 | 1.2.11.4.8 | Engage facilitators |  | 90d | 2019-10-01 A | 2020-01-30 A | 267 | 100% |  | 2019-10-01 | 2020-01-30 | 90d |  |  |  |
| 274 | 1.2.11.4.9 | Plan agenda |  | 80d | 2019-10-01 A | 2020-01-16 A | 267 | 100% |  | 2019-10-01 | 2020-01-16 | 80d |  |  |  |
| 275 | 1.2.11.4.10 | Confirm Day 0 work products (see tasks above) | milestone | 0d | 2020-03-23 A | 2020-03-23 A | 267, 313 | 100% |  | 2020-01-21 | 2020-01-21 | 0d |  |  |  |
| 276 | 1.2.11.4.11 | Day 0 preparations |  | 1d | 2020-01-27 A | 2020-01-27 A | 274 | 100% |  | 2020-01-27 | 2020-01-27 | 1d |  |  | start no earlier than 2020-01-27 |
| 277 | 1.2.11.4.12 | Day 1 sessions |  | 1d | 2020-01-28 A | 2020-01-28 A | 276 | 100% |  | 2020-01-28 | 2020-01-28 | 1d |  |  |  |
| 278 | 1.2.11.4.13 | Day 2 sessions |  | 1d | 2020-01-29 A | 2020-01-29 A | 277 | 100% |  | 2020-01-29 | 2020-01-29 | 1d |  |  |  |
| 279 | 1.2.11.4.14 | Day 3 sessions |  | 1d | 2020-01-30 A | 2020-01-30 A | 278 | 100% |  | 2020-01-30 | 2020-01-30 | 1d |  |  |  |
| 280 | 1.2.11.4.15 | F2F Recon and Sitrep | milestone | 0d | 2020-01-30 A | 2020-01-30 A | 279 | 100% |  | 2020-01-30 | 2020-01-30 | 0d |  |  |  |
| 281 | 1.2.11.4.16 | Communicate outcomes |  | 10d | 2020-01-31 A | 2020-02-13 A | 280 | 100% |  | 2020-01-31 | 2020-02-13 | 10d |  |  |  |
| 282 | 1.2.11.4.17 | Manage financial invoice, payment confirmation, and tracking (report to PCST) |  | 130d | 2019-10-01 A | 2020-03-26 | 267 | 80% | 26d | 2019-10-01 | 2020-03-26 | 130d | 175d | 0d |  |
| 283 | 1.2.11.4.18 | Close F2F | milestone | 0d | 2020-03-26 | 2020-03-26 | 282 |  |  | 2020-03-26 | 2020-03-26 | 0d | 175d |  |  |
| 284 | 1.2.11.5 | **EPDP Team F2F Meeting - Remote (07-12 Mar 2020)** |  | 155d | 2019-11-04 A | 2020-06-05 A |  | 100% |  | 2019-11-04 | 2020-06-05 | 155d |  |  |  |
| 285 | 1.2.11.5.1 | Determine requirements and scope |  | 1d | 2019-11-04 A | 2019-11-04 A | 261 | 100% |  | 2019-11-04 | 2019-11-04 | 1d |  |  |  |
| 286 | 1.2.11.5.2 | Obtain PCST approval |  | 5d | 2019-11-04 A | 2019-11-08 A | 261 | 100% |  | 2019-11-04 | 2019-11-08 | 5d |  |  |  |
| 287 | 1.2.11.5.3 | Interact with Meetings Team |  | 75d | 2019-11-11 A | 2020-02-21 A | 286 | 100% |  | 2019-11-11 | 2020-02-21 | 75d |  |  |  |
| 288 | 1.2.11.5.4 | Engage EPDP team to confirm RSVPs and manage applications for travel support |  | 30d | 2019-11-11 A | 2019-12-20 A | 286 | 100% |  | 2019-11-11 | 2019-12-20 | 30d |  |  |  |
| 289 | 1.2.11.5.5 | Engage facilitators | milestone | 0d | 2019-11-08 A | 2019-11-08 A | 286 | 100% |  | 2019-11-08 | 2019-11-08 | 0d |  |  |  |
| 290 | 1.2.11.5.6 | Plan agenda |  | 40d | 2019-11-11 A | 2020-01-03 A | 286 | 100% |  | 2019-11-11 | 2020-01-03 | 40d |  |  |  |
| 291 | 1.2.11.5.7 | Confirm Day 0 work products (see tasks above) | milestone | 0d | 2019-11-08 A | 2019-11-08 A | 286, 131 | 100% |  | 2019-11-08 | 2019-11-08 | 0d |  |  |  |
| 292 | 1.2.11.5.8 | Day 0 preparations |  | 1d | 2020-03-06 A | 2020-03-06 A | 290 | 100% |  | 2020-03-06 | 2020-03-06 | 1d |  |  | start no earlier than 2020-03-06 |
| 293 | 1.2.11.5.9 | Day 1 sessions |  | 1d | 2020-03-09 A | 2020-03-09 A | 292 | 100% |  | 2020-03-09 | 2020-03-09 | 1d |  |  | start no earlier than 2019-11-02 |
| 294 | 1.2.11.5.10 | Day 2 sessions |  | 1d | 2020-03-10 A | 2020-03-10 A | 293 | 100% |  | 2020-03-10 | 2020-03-10 | 1d |  |  | start no earlier than 2019-11-03 |
| 295 | 1.2.11.5.11 | F2F Recon and Sitrep | milestone | 0d | 2020-03-10 A | 2020-03-10 A | 294 | 100% |  | 2020-03-10 | 2020-03-10 | 0d |  |  |  |
| 296 | 1.2.11.5.12 | Communicate outcomes |  | 10d | 2020-03-11 A | 2020-03-24 A | 295 | 100% |  | 2020-03-11 | 2020-03-24 | 10d |  |  |  |
| 297 | 1.2.11.5.13 | Manage financial invoice, payment confirmation, and tracking (report to PCST) |  | 150d | 2019-11-11 A | 2020-06-05 A | 286 | 100% |  | 2019-11-11 | 2020-06-05 | 150d |  |  |  |
| 298 | 1.2.11.5.14 | Close F2F | milestone | 0d | 2020-06-05 A | 2020-06-05 A | 297 | 100% |  | 2020-06-05 | 2020-06-05 | 0d |  |  |  |

| ID | WBS | Task | Type | Duration | Start | Finish | Predecessors | Complete | Remaining | Baseline start | Baseline finish | Baseline duration | Total slack | Free slack |
| --- | --- | --- | --- | --- | --- | --- | --- | --- | --- | --- | --- | --- | --- | --- |
| 299 | 1.2.11.6 | **EPDP Team Leaders F2F Meeting [Travel Restricted & no longer planned]** |  | 332d | 2019-03-04 A | 2020-06-05 A |  | 100% |  | 2019-11-04 | 2020-06-05 | 155d |  |  |
| 300 | 1.2.11.6.1 | Determine requirements and scope |  | 1d | 2020-02-17 A | 2020-02-17 A | 312, 311 | 100% |  |  |  |  |  |  |
| 301 | 1.2.11.6.2 | Obtain PCST approval |  | 5d | 2020-02-17 A | 2020-02-21 A | 312, 311 | 100% |  |  |  |  |  |  |
| 302 | 1.2.11.6.3 | Interact with Meetings Team |  | 75d | 2020-02-24 A | 2020-06-05 A | 301 | 100% |  |  |  |  |  |  |
| 303 | 1.2.11.6.4 | Close F2F | milestone | 0d | 2019-03-04 A | 2019-03-04 A |  | 100% |  |  |  |  |  |  |
| 304 | 1.3 | **INITIAL REPORT** |  | 226d | 2019-06-28 A | 2020-05-06 A |  | 100% |  | 2019-06-28 | 2020-01-21 | 150d |  |  |
| 305 | 1.3.1 | Assemble initial conclusions |  | 90d | 2019-06-28 A | 2019-10-31 A | 37 | 100% |  | 2019-06-28 | 2019-10-31 | 90d |  |  |
| 306 | 1.3.2 | Populate discussion papers with findings and potential recommendations |  | 90d | 2019-06-28 A | 2019-10-31 A | 37 | 100% |  | 2019-06-28 | 2019-10-31 | 90d |  |  |
| 307 | 1.3.3 | Discuss/approve findings and interim recommendations |  | 6d | 2020-01-24 A | 2020-01-31 A | 131, 306, 34 | 100% |  | 2019-11-01 | 2019-11-12 | 10d |  |  |
| 308 | 1.3.4 | Consolidate interim recommendations and findings |  | 6d | 2020-01-24 A | 2020-01-31 A | 131, 306, 34 | 100% |  | 2019-11-01 | 2019-11-19 | 15d |  |  |
| 309 | 1.3.5 | Build Draft Report for public comment |  | 6d | 2020-01-24 A | 2020-01-31 A | 131, 306, 34 | 100% |  | 2019-11-01 | 2019-11-19 | 15d |  |  |
| 310 | 1.3.6 | Approve Draft Report for public comment |  | 5d | 2020-02-03 A | 2020-02-07 A | 307, 308, 309 | 100% |  | 2019-11-20 | 2019-12-03 | 10d |  |  |
| 311 | 1.3.7 | Publish Initial Report | milestone | 0d | 2020-02-07 A | 2020-02-07 A | 310, 214 | 100% |  | 2019-12-03 | 2019-12-03 | 0d |  |  |
| 312 | 1.3.8 | Communicate Initial Report |  | 5d | 2020-02-07 A | 2020-02-14 A | 214, 311 | 100% |  | 2019-12-03 | 2019-12-03 | 0d |  |  |
| 313 | 1.3.9 | Public comment forum on the Initial Report (45 days) |  | 31d | 2020-02-10 A | 2020-03-23 A | 310 | 100% |  | 2019-12-04 | 2020-01-21 | 35d |  |  |
| 314 | 1.3.10 | **Initial Report Addendum** |  | 63d | 2020-02-10 A | 2020-05-06 A |  | 100% |  |  |  |  |  |  |
| 315 | 1.3.10.1 | Assemble initial conclusions | manual | 28d | 2020-02-10 A | 2020-03-18 A | 311 | 100% |  |  |  |  |  |  |
| 316 | 1.3.10.2 | Populate draft addendum with findings and preliminary recommendations | manual | 28d | 2020-02-10 A | 2020-03-18 A | 311 | 100% |  |  |  |  |  |  |
| 317 | 1.3.10.3 | Discuss/approve findings and interim recommendations | manual | 28d | 2020-02-10 A | 2020-03-18 A | 311 | 100% |  |  |  |  |  |  |
| 318 | 1.3.10.4 | Publish Initial Report Addendum | manual | 4d | 2020-03-19 A | 2020-03-24 A | 317 | 100% |  |  |  |  |  |  |
| 319 | 1.3.10.5 | Public comment forum on the Initial Report Addendum (40 days) | manual | 30d | 2020-03-26 A | 2020-05-06 A | 318 | 100% |  |  |  |  |  |  |
| 320 | 1.4 | **FINAL REPORT** |  | 90d | 2020-02-07 A | 2020-06-11 |  | 60% | 36.22d | 2019-11-29 | 2020-04-21 | 103d | 120d |  |
| 321 | 1.4.1 | Review of public comments |  | 40d | 2020-03-24 A | 2020-05-18 | 313 | 85% | 6d | 2020-01-22 | 2020-02-25 | 25d | 1.25d | 0d |
| 322 | 1.4.2 | Continue deliberations of Priority 1 topics towards a Final Report |  | 40d | 2020-03-24 A | 2020-05-18 | 313 | 45% | 22d | 2020-01-22 | 2020-03-17 | 40d | 138d |  |
| 323 | 1.4.3 | Continue deliberations of Priority 2 topics towards a Final Report |  | 40d | 2020-03-24 A | 2020-05-18 | 313 | 20% | 32d | 2020-01-22 | 2020-03-17 | 40d | 138d |  |
| 324 | 1.4.4 | On-going review of legal questions / advice and interaction with counsel for Final Report |  | 72d | 2020-02-07 A | 2020-05-18 A | 214 | 100% |  | 2019-11-29 | 2020-04-16 | 100d |  |  |
| 325 | 1.4.5 | Build Final Report & Final Deliberations |  | 5d | 2020-05-19 A | 2020-05-25 | 321 | 25% | 3.75d | 2020-02-26 | 2020-03-31 | 25d | 0d |  |
| 326 | 1.4.6 | Determine consensus levels on interim recommendations |  | 13d | 2020-05-26 | 2020-06-11 | 325 |  |  | 2020-04-01 | 2020-04-14 | 10d | 120d |  |
| 327 | 1.4.7 | Adopt final recommendations and report |  | 13d | 2020-05-26 | 2020-06-11 | 325 |  |  | 2020-04-15 | 2020-04-21 | 5d | 0d |  |
| 328 | 1.4.8 | Submission of Final Report to the GNSO Council | milestone | 0d | 2020-06-11 | 2020-06-11 | 327 |  |  | 2020-04-21 | 2020-04-21 | 0d | 0d |  |

| ID | WBS | Task | Duration | Start | Finish | Predecessors | Baseline start | Baseline finish | Baseline duration | Total slack |
| --- | --- | --- | --- | --- | --- | --- | --- | --- | --- | --- |
| 329 | 1.5 | **POST EPDP ACTIVITIES** | 100d | 2020-06-12 | 2020-10-29 |  | 2020-04-22 | 2020-09-08 | 100d | 0d |
| 330 | 1.5.1 | Approval of Final Report and Recommendations by the GNSO Council | 40d | 2020-06-12 | 2020-08-06 | 328 | 2020-04-22 | 2020-06-16 | 40d | 0d |
| 331 | 1.5.2 | Report to the Board | 20d | 2020-08-07 | 2020-09-03 | 330 | 2020-06-17 | 2020-07-14 | 20d | 60d |
| 332 | 1.5.3 | Publish Recommendations for Public Comment | 35d | 2020-08-07 | 2020-09-24 | 330 | 2020-06-17 | 2020-08-04 | 35d | 0d |
| 333 | 1.5.4 | Inform GAC if Recommendations affect public policy | 35d | 2020-08-07 | 2020-09-24 | 330 | 2020-06-17 | 2020-08-04 | 35d | 45d |
| 334 | 1.5.5 | Board Paper | 20d | 2020-09-25 | 2020-10-22 | 332 | 2020-08-05 | 2020-09-01 | 20d | 0d |
| 335 | 1.5.6 | Board consideration / approval | 5d | 2020-10-23 | 2020-10-29 | 334 | 2020-09-02 | 2020-09-08 | 5d | 0d |
